# DIAGRAMA GRANTT EFRAIN ARCAYA

Schedule from MS Project, 2022-03-01 to 2024-02-29, costs in S..

## Calendars

- Estándar: Mon-Sat 08:00-13:00, 14:00-17:00; Sun off.

## Schedule

| ID | WBS | Task | Type | Duration | Start | Finish | Predecessors | Total slack | Free slack | Cost | Text1 |
| --- | --- | --- | --- | --- | --- | --- | --- | --- | --- | --- | --- |
| 1 | 1 | **MEJORAMIENTO DEL SERVICIO DE EDUCACIÓN BASICA REGULAR DE LA INSTITUCION EDUCATIVA N° 093 EFRAIN ARCAYA ZEVALLOS DEL DISTRITO DE ZARUMILLA- PROVINCIA DE ZARUMILLA-DEPARTAMENTO DE TUMBES** |  | 626d | 2022-03-01 | 2024-02-29 |  | 0d |  | 25,219,733.8 |  |
| 2 | 1.1 | INICIO DEL PROYECTO | milestone | 0d | 2022-03-01 | 2022-03-01 |  | 0d |  |  |  |
| 3 | 1.2 | **OBRAS PROVISIONALES Y PRELIMINARES** |  | 600d | 2022-03-01 | 2024-01-30 |  | 6d |  | 1,310,128.69 | 01 |
| 4 | 1.2.1 | **OBRAS PROVISIONALES** |  | 7d | 2022-03-01 | 2022-03-09 |  | 619d |  | 17,128.14 | 01.01 |
| 5 | 1.2.1.1 | SUMINISTRO Y COLOCACION DE CARTEL DE OBRA DE 2.40 x 3.60m |  | 1d | 2022-03-01 | 2022-03-02 | 2 | 619d | 0d | 731.75 | 01.01.01 |
| 6 | 1.2.1.2 | CASETA DE GUARDIANIA Y/O ALMACEN |  | 6d | 2022-03-02 | 2022-03-09 | 5 | 619d | 0d | 3,143.04 | 01.01.02 |
| 7 | 1.2.1.3 | COMEDOR PARA PERSONAL OBRERO |  | 6d | 2022-03-02 | 2022-03-09 | 6SS | 619d | 0d | 3,928.8 | 01.01.03 |
| 8 | 1.2.1.4 | VESUARIO PARA PERSONAL |  | 6d | 2022-03-02 | 2022-03-09 | 7SS | 619d | 0d | 785.76 | 01.01.04 |
| 9 | 1.2.1.5 | CERCO PROVISIONAL EN OBRA DE CALAMINA GALVANIZADA h=2.20m |  | 6d | 2022-03-02 | 2022-03-09 | 8SS | 619d |  | 8,538.79 | 01.01.05 |
| 10 | 1.2.2 | **TRABAJOS PRELIMINARES** |  | 301d | 2022-03-08 | 2023-02-22 |  | 0d |  | 309,175.31 | 01.02 |
| 11 | 1.2.2.1 | TRAZO, NIVELES Y REPLANTEO |  | 300d | 2022-03-09 | 2023-02-22 | 12SS+1d | 0d |  | 32,045.92 | 01.02.01 |
| 12 | 1.2.2.2 | LIMPIEZA INICIAL DE OBRA |  | 35d | 2022-03-08 | 2022-04-18 | 2SS+6d | 0d |  | 14,360.2 | 01.02.02 |
| 13 | 1.2.2.3 | MOVILIZACION Y DESMOVILIZACION DE EQUIPO |  | 90d | 2022-03-09 | 2022-06-22 | 11SS | 529d |  | 8,156.8 | 01.02.03 |
| 14 | 1.2.2.4 | TALA DE ARBOLES INC/REFORESTACION |  | 6d | 2022-03-10 | 2022-03-17 | 12SS+2d | 612d |  | 6,125.5 | 01.02.04 |
| 15 | 1.2.2.5 | **SERVICIOS HIGIENICOS PROVISIONALES** |  | 14d | 2022-03-09 | 2022-03-25 |  | 586d |  | 26,197.3 | 01.02.05 |
| 16 | 1.2.2.5.1 | CAPA DE MATERIAL DE PRESTAMO - HORMIGON e=0.20m CON EQUIPO LIVIANO |  | 1d | 2022-03-09 | 2022-03-10 | 11SS | 586d | 0d | 415.82 | 01.02.05.01 |
| 17 | 1.2.2.5.2 | LOSA DE CONCRETO F'C=140 KG/CM2, e=10cm/ACABADO FROTACHADO (INC. ENCOFRADO) |  | 1d | 2022-03-18 | 2022-03-19 | 78 | 586d | 0d | 1,237.06 | 01.02.05.02 |
| 18 | 1.2.2.5.3 | SARDINEL DE CONCRETO (0.20x0.40 ) F'C=140 KG/CM2 |  | 1d | 2022-03-18 | 2022-03-19 | 17SS | 586d | 0d | 698.59 | 01.02.05.03 |
| 19 | 1.2.2.5.4 | SUMINISTRO E INSTALACION DE COLUMNAS DE MADERA DE 4" x 4" |  | 6d | 2022-03-18 | 2022-03-25 | 18SS | 605d | 0d | 3,514.65 | 01.02.05.04 |
| 20 | 1.2.2.5.5 | SUMINISTRO E INSTALACION DE PANELES DE FIBRO CEMENTO ST DE 6mm |  | 6d | 2022-03-18 | 2022-03-25 | 19SS | 605d |  | 7,520.73 | 01.02.05.05 |
| 21 | 1.2.2.5.6 | SUMINISTRO E INSTALACION DE VIGAS DE MADERA DE 2" x 4" |  | 6d | 2022-03-18 | 2022-03-25 | 18SS | 586d | 0d | 415.03 | 01.02.05.06 |
| 22 | 1.2.2.5.7 | PLANCHAS DE PROLIPROPILENO DE e=1.2mm/COLOR ROJO - INCLUYE CORREAS DE MADERA 2" x 2" |  | 6d | 2022-03-18 | 2022-03-25 | 21SS | 586d | 0d | 983.34 | 01.02.05.07 |
| 23 | 1.2.2.5.8 | SUMINISTRO E INSTALACION DE PUERTAS DE TRIPLAY CON MARCO DE MADERA (0.90x2.10) INCL. CERRAJERIA |  | 6d | 2022-03-18 | 2022-03-25 | 22SS | 586d | 0d | 400 | 01.02.05.08 |
| 24 | 1.2.2.5.9 | SUMINISTRO E INSTALACION DE PUERTAS DE TRIPLAY CON MARCO DE MADERA (0.60x1.60) INCL. CERRAJERIA |  | 6d | 2022-03-18 | 2022-03-25 | 23SS | 586d | 0d | 720 | 01.02.05.09 |
| 25 | 1.2.2.5.10 | SUMINISTRO Y COLOCACION DE VENTANAS (2.00x0.60m) INC. CELOCIA Y MARCO DE MADERA |  | 6d | 2022-03-18 | 2022-03-25 | 24SS | 586d | 0d | 220 | 01.02.05.10 |
| 26 | 1.2.2.5.11 | SARD. DE Cº 0.20x0.50 F'C=140 KG/CM2 |  | 6d | 2022-03-18 | 2022-03-25 | 25SS | 586d | 0d | 412.7 | 01.02.05.11 |
| 27 | 1.2.2.5.12 | TARRAJEO DE SARD. DE Cº 0.20x0.50 |  | 6d | 2022-03-18 | 2022-03-25 | 26SS | 586d | 0d | 224.72 | 01.02.05.12 |
| 28 | 1.2.2.5.13 | PINTURA CON ESMALTE SINTETICO |  | 6d | 2022-03-18 | 2022-03-25 | 27SS | 586d | 0d | 826.75 | 01.02.05.13 |
| 29 | 1.2.2.5.14 | LAVADERO DE UNA POZA ACABADO PULIDO INC./INSTALACIONES |  | 6d | 2022-03-18 | 2022-03-25 | 28SS | 586d | 0d | 520 | 01.02.05.14 |
| 30 | 1.2.2.5.15 | COLOCACION DE TORRE METALICA PARA TANQUE DE AGUA SEGUN DISEÑO |  | 6d | 2022-03-18 | 2022-03-25 | 29SS | 586d | 0d | 1,700 | 01.02.05.15 |

| ID | WBS | Task | Duration | Start | Finish | Predecessors | Total slack | Free slack | Cost | Text1 |
| --- | --- | --- | --- | --- | --- | --- | --- | --- | --- | --- |
| 31 | 1.2.2.5.16 | **APARATOS SANITARIOS Y ACCESORIOS** | 6d | 2022-03-18 | 2022-03-25 |  | 586d |  | 1,979.12 | 01.02.05.16 |
| 32 | 1.2.2.5.16.1 | SUMINISTRO DE APARATOS SANITARIO (INODORO) | 6d | 2022-03-18 | 2022-03-25 | 30SS | 586d | 0d | 1,017 | 01.02.05.16.01 |
| 33 | 1.2.2.5.16.2 | SUMINISTRO DE APARATOS SANITARIOS (DUCHAS) | 6d | 2022-03-18 | 2022-03-25 | 32SS | 586d | 0d | 188.7 | 01.02.05.16.02 |
| 34 | 1.2.2.5.16.3 | SUMINISTRO DE ACCESORIOS P/INODOROS | 6d | 2022-03-18 | 2022-03-25 | 33SS | 586d | 0d | 95.91 | 01.02.05.16.03 |
| 35 | 1.2.2.5.16.4 | SUMINISTRO DEACCESORIOS P/DUCHAS | 6d | 2022-03-18 | 2022-03-25 | 34SS | 586d | 0d | 0.51 | 01.02.05.16.04 |
| 36 | 1.2.2.5.16.5 | INSTALACION DE APARATOS SANITARIOS Y ACCESORIOS | 6d | 2022-03-18 | 2022-03-25 | 35SS | 586d | 0d | 677 | 01.02.05.16.05 |
| 37 | 1.2.2.5.17 | **SISTEMA DE AGUA FRIA** | 3d | 2022-03-10 | 2022-03-14 |  | 586d |  | 435.9 | 01.02.05.17 |
| 38 | 1.2.2.5.17.1 | SALIDA DE AGUA FRIA Ø 1/2" BRONCE | 3d | 2022-03-10 | 2022-03-14 | 16 | 586d | 0d | 435.9 | 01.02.05.17.01 |
| 39 | 1.2.2.5.18 | **REDES DE DISTRIBUCION** | 3d | 2022-03-10 | 2022-03-14 |  | 586d |  | 235.57 | 01.02.05.18 |
| 40 | 1.2.2.5.18.1 | TUBERIA PVC CLASE 10 SP P/AGUA FRIA D=3/4" | 3d | 2022-03-10 | 2022-03-14 | 38SS | 586d | 0d | 235.57 | 01.02.05.18.01 |
| 41 | 1.2.2.5.19 | **REDES DE ALIMENTACION** | 3d | 2022-03-10 | 2022-03-14 |  | 586d |  | 20.95 | 01.02.05.19 |
| 42 | 1.2.2.5.19.1 | TUBERIA PVC CLASE 10 SP P/AGUA FRIA D=3/4" | 3d | 2022-03-10 | 2022-03-14 | 40SS | 586d | 0d | 20.95 | 01.02.05.19.01 |
| 43 | 1.2.2.5.20 | **ACCESORIOS DE REDES DE AGUA** | 3d | 2022-03-10 | 2022-03-14 |  | 586d |  | 717.55 | 01.02.05.20 |
| 44 | 1.2.2.5.20.1 | SUMINISTRO E INSTALACION DE CODO DE 90° PVC AGUA C-10 3/4" | 3d | 2022-03-10 | 2022-03-14 | 42SS | 586d | 0d | 161.33 | 01.02.05.20.01 |
| 45 | 1.2.2.5.20.2 | SUMINISTRO E INSTALACION DE TEE PVC SAP DE Ø 1" | 3d | 2022-03-10 | 2022-03-14 | 44SS | 586d | 0d | 19.42 | 01.02.05.20.02 |
| 46 | 1.2.2.5.20.3 | SUMINISTRO E INSTALACION DE TEE PVC AGUA C-10 3/4" | 3d | 2022-03-10 | 2022-03-14 | 45SS | 586d | 0d | 82.8 | 01.02.05.20.03 |
| 47 | 1.2.2.5.20.4 | SUMINISTRO E INSTALACION DE CODO DE BRONCE 1/2" | 3d | 2022-03-10 | 2022-03-14 | 46SS | 586d | 0d | 93.7 | 01.02.05.20.04 |
| 48 | 1.2.2.5.20.5 | SUMINISTRO E INSTALACION DE ADAPTADOR PVC AGUA C-10 3/4" | 3d | 2022-03-10 | 2022-03-14 | 47SS | 586d | 0d | 80.5 | 01.02.05.20.05 |
| 49 | 1.2.2.5.20.6 | SUMINISTRO E INSTALACION DE NIPLE PVC AGUA C-10 3/4" | 3d | 2022-03-10 | 2022-03-14 | 48SS | 586d | 0d | 36.2 | 01.02.05.20.06 |
| 50 | 1.2.2.5.20.7 | SUMINISTRO E INSTALACION DE REDUCCION PVC AGUA C-10 1" A 3/4" | 3d | 2022-03-10 | 2022-03-14 | 49SS | 586d | 0d | 9.94 | 01.02.05.20.07 |
| 51 | 1.2.2.5.20.8 | SUMINISTRO E INSTALACION DE REDUCCION PVC AGUA C-10 3/4 A 1/2" | 3d | 2022-03-10 | 2022-03-14 | 50SS | 586d | 0d | 83.8 | 01.02.05.20.08 |
| 52 | 1.2.2.5.20.9 | SUMINISTRO E INSTALACION DE TUBO DE ABASTO PARA INODORO | 3d | 2022-03-10 | 2022-03-14 | 51SS | 586d | 0d | 89.04 | 01.02.05.20.09 |
| 53 | 1.2.2.5.20.10 | SUMINISTRO E INSTALACION DE TRAMPA PLASTICA C/REGISTRO | 3d | 2022-03-10 | 2022-03-14 | 52SS | 586d | 0d | 29.68 | 01.02.05.20.10 |
| 54 | 1.2.2.5.20.11 | SUMINISTRO E INSTALACION DE UNION UNIVERSAL PVC 3/4" | 3d | 2022-03-10 | 2022-03-14 | 53SS | 586d | 0d | 31.14 | 01.02.05.20.11 |

| ID | WBS | Task | Duration | Start | Finish | Predecessors | Total slack | Free slack | Cost | Text1 |
| --- | --- | --- | --- | --- | --- | --- | --- | --- | --- | --- |
| 55 | 1.2.2.5.21 | **VALVULAS** | 3d | 2022-03-10 | 2022-03-14 |  | 586d |  | 83.18 | 01.02.05.21 |
| 56 | 1.2.2.5.21.1 | VALVULA COMPUERTA PESADA DE BRONCE DE 3/4" | 3d | 2022-03-10 | 2022-03-14 | 54SS | 586d | 0d | 83.18 | 01.02.05.21.01 |
| 57 | 1.2.2.5.22 | **ALMACENAMIENTO DE AGUA** | 3d | 2022-03-14 | 2022-03-17 |  | 586d |  | 1,860.35 | 01.02.05.22 |
| 58 | 1.2.2.5.22.1 | SUMINISTRO E INSTALACION DE TANQUE DE POLIETILENO CAP. 1100 LT | 3d | 2022-03-14 | 2022-03-17 | 56 | 586d | 0d | 760.26 | 01.02.05.22.01 |
| 59 | 1.2.2.5.22.2 | SUMINISTRO E INSTALACION DE CISTERNA DE POLIETILENO CAP. 1200 LT | 3d | 2022-03-14 | 2022-03-17 | 58SS | 586d | 0d | 1,100.09 | 01.02.05.22.02 |
| 60 | 1.2.2.5.23 | **DESAGUE Y VENTILACION** | 3d | 2022-03-15 | 2022-03-18 |  | 586d |  | 348.5 | 01.02.05.23 |
| 61 | 1.2.2.5.23.1 | SALIDAS DE DESAGUE DE PVC 4" | 3d | 2022-03-15 | 2022-03-18 | 59SS+1d | 586d | 0d | 152.55 | 01.02.05.23.01 |
| 62 | 1.2.2.5.23.2 | SALIDAS DE DESAGUE DE PVC 2" | 3d | 2022-03-15 | 2022-03-18 | 61SS | 586d | 0d | 195.95 | 01.02.05.23.02 |
| 63 | 1.2.2.5.24 | **REDES DE DERIVACION** | 3d | 2022-03-15 | 2022-03-18 |  | 586d |  | 170.31 | 01.02.05.24 |
| 64 | 1.2.2.5.24.1 | TUBO DE DESAGUE DE PVC Ø 4" | 3d | 2022-03-15 | 2022-03-18 | 62SS | 586d | 0d | 105.84 | 01.02.05.24.01 |
| 65 | 1.2.2.5.24.2 | TUBO DE DESAGUE DE PVC Ø 2" | 3d | 2022-03-15 | 2022-03-18 | 64SS | 586d | 0d | 64.47 | 01.02.05.24.02 |
| 66 | 1.2.2.5.25 | **REDES COLECTORAS** | 3d | 2022-03-15 | 2022-03-18 |  | 586d |  | 82.82 | 01.02.05.25 |
| 67 | 1.2.2.5.25.1 | TUBERIA DE DESAGUE PVC SAP D= 4" | 3d | 2022-03-15 | 2022-03-18 | 65SS | 586d | 0d | 82.82 | 01.02.05.25.01 |
| 68 | 1.2.2.5.26 | **ACCESORIOS DE REDES DE DESAGUE** | 3d | 2022-03-15 | 2022-03-18 |  | 586d |  | 327.89 | 01.02.05.26 |
| 69 | 1.2.2.5.26.1 | SUMINISTRO E INSTALACION DE CODO 90° PVC Ø 4" | 3d | 2022-03-15 | 2022-03-18 | 67SS | 586d | 0d | 22.32 | 01.02.05.26.01 |
| 70 | 1.2.2.5.26.2 | SUMINISTRO E INSTALACION DE CODO 90° PVC Ø 2" | 3d | 2022-03-15 | 2022-03-18 | 69SS | 586d | 0d | 25.86 | 01.02.05.26.02 |
| 71 | 1.2.2.5.26.3 | SUMINISTRO E INSTALACION DE REGISTRO DE BRONCE DE Ø 4" | 3d | 2022-03-15 | 2022-03-18 | 70SS | 586d | 0d | 13.77 | 01.02.05.26.03 |
| 72 | 1.2.2.5.26.4 | SUMINISTRO Y COLOCACION DE SUMIDERO CON TRAMPA P | 3d | 2022-03-15 | 2022-03-18 | 71SS | 586d | 0d | 102.12 | 01.02.05.26.04 |
| 73 | 1.2.2.5.26.5 | SUMINISTRO E INSTALACION DE TEE PVC 4" | 3d | 2022-03-15 | 2022-03-18 | 72SS | 586d | 0d | 15.62 | 01.02.05.26.05 |
| 74 | 1.2.2.5.26.6 | SUMINISTRO E INSTALACIÓN DE YEE SIMPLE 4" | 3d | 2022-03-15 | 2022-03-18 | 73SS | 586d | 0d | 45.66 | 01.02.05.26.06 |
| 75 | 1.2.2.5.26.7 | SUMINISTRO E INSTALACIÓN DE YEE DE 4" A 2" | 3d | 2022-03-15 | 2022-03-18 | 74SS | 586d | 0d | 78.2 | 01.02.05.26.07 |
| 76 | 1.2.2.5.26.8 | SUMINISTRO E INSTALACIÓN DE SOMBRERO DE VENTILACION 4" | 3d | 2022-03-15 | 2022-03-18 | 75SS | 586d | 0d | 24.34 | 01.02.05.26.08 |
| 77 | 1.2.2.5.27 | **CAMARAS DE INSPECCION** | 3d | 2022-03-15 | 2022-03-18 |  | 586d |  | 125.77 | 01.02.05.27 |
| 78 | 1.2.2.5.27.1 | SUMINISTRO E INSTALACION DE CAJA DE REGISTRO | 3d | 2022-03-15 | 2022-03-18 | 76SS | 586d | 0d | 125.77 | 01.02.05.27.01 |

| ID | WBS | Task | Duration | Start | Finish | Predecessors | Total slack | Free slack | Cost | Text1 |
| --- | --- | --- | --- | --- | --- | --- | --- | --- | --- | --- |
| 79 | 1.2.2.6 | **DEMOLICION Y DESMONTAJE** | 25d | 2022-03-18 | 2022-04-16 |  | 586d |  | 222,289.59 | 01.02.06 |
| 80 | 1.2.2.6.1 | DEMOLICION DE EDIFICACION EXISTENTE C/MAQUINARIA | 25d | 2022-03-18 | 2022-04-16 | 36SS | 586d | 0d | 147,618.53 | 01.02.06.01 |
| 81 | 1.2.2.6.2 | DEMOLICION MANUAL DE CUNETAS EXISTENTES | 25d | 2022-03-18 | 2022-04-16 | 80SS | 586d | 0d | 3,860.67 | 01.02.06.02 |
| 82 | 1.2.2.6.3 | DESMONTAJE DE APARATOS SANITARIOS EXISTENTES, MANUAL | 25d | 2022-03-18 | 2022-04-16 | 81SS | 586d | 0d | 77.22 | 01.02.06.03 |
| 83 | 1.2.2.6.4 | DESMONTAJE DE COBERTURA EN EDIFICACION EXISTENTE | 25d | 2022-03-18 | 2022-04-16 | 82SS | 586d | 0d | 13,850.91 | 01.02.06.04 |
| 84 | 1.2.2.6.5 | DESMONTAJE DE CERCO, VENTANAS Y PUERTAS METALICAS | 25d | 2022-03-18 | 2022-04-16 | 83SS | 586d | 0d | 9,958.75 | 01.02.06.05 |
| 85 | 1.2.2.6.6 | DESMONTAJE DE AULA DE DRYWALL EXISTENTE MANUAL | 25d | 2022-03-18 | 2022-04-16 | 84SS | 586d | 0d | 3,385.61 | 01.02.06.06 |
| 86 | 1.2.2.6.7 | DESMONTAJE MANUA DE AULA PREFABRICADA DE MATERIAL TERMICO INC. PUERTAS Y VENTANAS | 25d | 2022-03-18 | 2022-04-16 | 85SS | 586d | 0d | 27,433.89 | 01.02.06.07 |
| 87 | 1.2.2.6.8 | DESMONTAJE MANUAL DE ESTRUCTURA METALICA PARA COBERTURA DE MALLA RASCHELL EXISTENTE | 25d | 2022-03-18 | 2022-04-16 | 86SS | 586d | 0d | 1,113.45 | 01.02.06.08 |
| 88 | 1.2.2.6.9 | DESMONTAJE DE CANTONERAS METALICAS EXISTENTE, MANUAL | 25d | 2022-03-18 | 2022-04-16 | 87SS | 586d | 0d | 363.52 | 01.02.06.09 |
| 89 | 1.2.2.6.10 | DESMONTAJE DE PASAMANOS METALICOS EXISTENTES, MANUAL | 25d | 2022-03-18 | 2022-04-16 | 88SS | 586d | 0d | 76.33 | 01.02.06.10 |
| 90 | 1.2.2.6.11 | DESMONTAJE DE GRUTAS Y BUSTOS EXISTENTE MANUAL | 25d | 2022-03-18 | 2022-04-16 | 89SS | 586d | 0d | 512.98 | 01.02.06.11 |
| 91 | 1.2.2.6.12 | DESMONTAJE DE ASTA DE BANDERA EXISTENTE, MANUAL | 25d | 2022-03-18 | 2022-04-16 | 90SS | 586d | 0d | 544.28 | 01.02.06.12 |
| 92 | 1.2.2.6.13 | DESMONTAJE DE DEPOSITO PARA BASURA EXISTENTE, MANUAL | 25d | 2022-03-18 | 2022-04-16 | 91SS | 586d | 0d | 85.44 | 01.02.06.13 |
| 93 | 1.2.2.6.14 | DESMONTAJE DE PARANTES DE MADERA EXISTENTE, MANUAL | 25d | 2022-03-18 | 2022-04-16 | 92SS | 586d | 0d | 256.4 | 01.02.06.14 |
| 94 | 1.2.2.6.15 | DESMONTAJE DE TIJERALES METALICOS EXISTENTES, MANUAL | 25d | 2022-03-18 | 2022-04-16 | 93SS | 586d | 0d | 1,659.6 | 01.02.06.15 |
| 95 | 1.2.2.6.16 | TRANSPORTE DE MATERIAL PARA MONTAJE DE AULAS PREFABRICADAS DE MATERIAL TERMICO | 25d | 2022-03-18 | 2022-04-16 | 94SS | 586d |  | 11,492.01 | 01.02.06.16 |
| 96 | 1.2.3 | **SEGURIDAD EN OBRA Y PLAN PARA LA VIGILANCIA, PREVENCION Y CONTROL DE LA COVID-19** | 600d | 2022-03-01 | 2024-01-30 |  | 26d |  | 127,827.3 | 01.03 |
| 97 | 1.2.3.1 | **SEGURIDAD EN OBRA** | 600d | 2022-03-01 | 2024-01-30 |  | 26d |  | 14,321.84 | 01.03.01 |
| 98 | 1.2.3.1.1 | EQUIPO DE PROTECCION COLECCTIVA | 600d | 2022-03-01 | 2024-01-30 | 2SS | 26d | 0d | 2,999.4 | 01.03.01.01 |
| 99 | 1.2.3.1.2 | EQUIPO DE PROTECCION INDIVIDUAL | 600d | 2022-03-01 | 2024-01-30 | 98SS | 26d | 0d | 9,401.8 | 01.03.01.02 |
| 100 | 1.2.3.1.3 | SEÑALIZACION TEMPORAL EN OBRA | 600d | 2022-03-01 | 2024-01-30 | 99SS | 26d | 0d | 1,920.64 | 01.03.01.03 |
| 101 | 1.2.3.2 | **PLAN PARA LA PREVENCION Y CONTROL ANTE LA COVID-19 EN OBRA** | 600d | 2022-03-01 | 2024-01-30 |  | 26d |  | 113,505.46 | 01.03.02 |
| 102 | 1.2.3.2.1 | EQUIPO DE PROTECCION INDIVIDUAL PARA PERSONAL DE OBRA | 600d | 2022-03-01 | 2024-01-30 | 100SS | 26d | 0d | 14,437.2 | 01.03.02.01 |
| 103 | 1.2.3.2.2 | EQUIPO DE PROTECCION INDIVIDUAL PARA DIRECCION DE OBRA | 600d | 2022-03-01 | 2024-01-30 | 102SS | 26d | 0d | 23,897.04 | 01.03.02.02 |
| 104 | 1.2.3.2.3 | EQUIPO DE PROTECCION INDIVIDUAL PARA PERSONAL DE SALUD | 600d | 2022-03-01 | 2024-01-30 | 103SS | 26d | 0d | 8,379.12 | 01.03.02.03 |
| 105 | 1.2.3.2.4 | IDENTIFICACIÓN DE SINTOMATOLOGÍA COVID-19 PERIÓDICAMENTE AL INGRESO DE OBRA | 600d | 2022-03-01 | 2024-01-30 | 104SS | 26d | 0d | 52,676.16 | 01.03.02.04 |
| 106 | 1.2.3.2.5 | KIT PARA LAVADO Y DESINFECCION DE PERSONAL | 600d | 2022-03-01 | 2024-01-30 | 105SS | 26d | 0d | 7,604.88 | 01.03.02.05 |
| 107 | 1.2.3.2.6 | EQUIPAMIENTO PARA VIGILANCIA DE LA SALUD DEL TRABAJADOR | 600d | 2022-03-01 | 2024-01-30 | 106SS | 26d | 0d | 1,757.78 | 01.03.02.06 |
| 108 | 1.2.3.2.7 | EQUIPAMIENTO PARA DESINFECCIÓN DE ÁREAS COMUNES | 600d | 2022-03-01 | 2024-01-30 | 107SS | 26d | 0d | 2,210.85 | 01.03.02.07 |
| 109 | 1.2.3.2.8 | IMPLEMENTACION DE AREA DE TRIAJE (CONTROL PREVIO) | 2d | 2022-03-03 | 2022-03-05 | 108SS+2d | 622d |  | 2,542.43 | 01.03.02.08 |

| ID | WBS | Task | Duration | Start | Finish | Predecessors | Total slack | Free slack | Cost | Text1 |
| --- | --- | --- | --- | --- | --- | --- | --- | --- | --- | --- |
| 110 | 1.2.4 | **PLAN DE CONTINGENCIA** | 70d | 2022-03-10 | 2022-05-31 |  | 548d |  | 802,304.57 | 01.04 |
| 111 | 1.2.4.1 | TRAZO, NIVELACION Y REPLANTEO | 3d | 2022-03-10 | 2022-03-14 | 11SS+1d | 548d | 0d | 6,372.47 | 01.04.01 |
| 112 | 1.2.4.2 | CORTE DE TERRENO NATURAL CON MAQUINARIA | 4d | 2022-03-10 | 2022-03-15 | 111SS | 548d | 0d | 6,641.33 | 01.04.02 |
| 113 | 1.2.4.3 | CAPA DE MATERIAL DE PRESTAMO - HORMIGON e=0.15m CON EQUIPO PESADO | 3d | 2022-03-14 | 2022-03-17 | 112FS-1d | 548d | 0d | 39,797.85 | 01.04.03 |
| 114 | 1.2.4.4 | SUMINISTRO E INSTALACION DE PANELES DE TRIPLAY DE 1.20x2.40 DE 4mm | 22d | 2022-04-08 | 2022-05-04 | 116SS+2d | 548d | 0d | 136,167.61 | 01.04.04 |
| 115 | 1.2.4.5 | SUMINISTRO E INSTALACION DE PANELES DE FIBROCEMENTO TIPO ST DE 6mm | 22d | 2022-04-08 | 2022-05-04 | 114SS | 548d | 0d | 32,355.85 | 01.04.05 |
| 116 | 1.2.4.6 | SUMINISTRO E INSTALACION DE COLUMNAS DE MADERA DE 4" x 4" | 8d | 2022-04-06 | 2022-04-15 | 126FS-6d | 548d | 0d | 23,745.85 | 01.04.06 |
| 117 | 1.2.4.7 | SUMINISTRO E INSTALACION DE VIGAS DE MADERA DE 2" x 4" | 8d | 2022-04-27 | 2022-05-06 | 115FS-6d | 548d | 0d | 15,305.39 | 01.04.07 |
| 118 | 1.2.4.8 | PUERTAS DE TRIPLAY Y MARCO DE MADERA (1.00x2.10) INCL. CERROJO Y CANDADO | 8d | 2022-05-10 | 2022-05-19 | 123FS-5d | 548d | 0d | 9,900 | 01.04.08 |
| 119 | 1.2.4.9 | PUERTAS DE TRIPLAY Y MARCO DE MADERA (0.90x2.10) INCL. CERROJO Y CANDADO | 8d | 2022-05-10 | 2022-05-19 | 118SS | 548d | 0d | 1,600 | 01.04.09 |
| 120 | 1.2.4.10 | PUERTAS DE TRIPLAY Y MARCO DE MADERA (0.60x2.10) INCL. CERROJO Y CANDADO | 8d | 2022-05-10 | 2022-05-19 | 119SS | 548d | 0d | 1,920 | 01.04.10 |
| 121 | 1.2.4.11 | SUMINISTRO Y COLOCACION DE BISAGRA DE 4" EN PUERTAS | 8d | 2022-05-10 | 2022-05-19 | 120SS | 548d | 0d | 1,643.85 | 01.04.11 |
| 122 | 1.2.4.12 | SUMINISTRO Y COLOCACION DE VENTANAS INC. CELOCIA Y MARCO DE MADERA | 8d | 2022-05-10 | 2022-05-19 | 121SS | 548d | 0d | 38,001.2 | 01.04.12 |
| 123 | 1.2.4.13 | PLANCHAS DE PROLIPROPILENO DE e=1.2mm/COLOR ROJO - INCLUYE CORREAS DE MADERA 2" x 2" | 12d | 2022-05-02 | 2022-05-16 | 117FS-4d | 548d | 0d | 84,850.83 | 01.04.13 |
| 124 | 1.2.4.14 | LOSA DE CONCRETO F'C=140 KG/CM2, e=10cm/ACABADO FROTACHADO (INC. ENCOFRADO) | 15d | 2022-03-26 | 2022-04-13 | 189 | 548d | 0d | 158,851.89 | 01.04.14 |
| 125 | 1.2.4.15 | JUNTA ASFALTICA e=1" EN LOSA | 15d | 2022-03-26 | 2022-04-13 | 124SS | 548d | 0d | 2,728.6 | 01.04.15 |
| 126 | 1.2.4.16 | DADOS DE CONCRETO (0.35x0.35x0.50m) F'C=140 KG/CM2 | 15d | 2022-03-26 | 2022-04-13 | 125SS | 548d | 0d | 11,080.74 | 01.04.16 |
| 127 | 1.2.4.17 | SUMINISTRO Y COLOCACION DE PANEL CERCA PRO 2.40x3.00m, COLOR VERDE SEGUN DISEÑO INC. PARANTES METALICOS 3" x 3" x 3.00m | 18d | 2022-05-10 | 2022-05-31 | 122SS | 548d | 0d | 90,523.71 | 01.04.17 |
| 128 | 1.2.4.18 | SARDINEL (0.20x0.40) F'C=140 KG/CM2 | 18d | 2022-05-10 | 2022-05-31 | 127SS | 548d | 0d | 36,831.42 | 01.04.18 |
| 129 | 1.2.4.19 | SARDINEL (0.20x0.50 ) F'C=140 KG/CM2 | 18d | 2022-05-10 | 2022-05-31 | 128SS | 548d | 0d | 585.32 | 01.04.19 |
| 130 | 1.2.4.20 | TARRAJEO DE SARDINEL (0.20x0.50) | 18d | 2022-05-10 | 2022-05-31 | 129SS | 548d | 0d | 315.15 | 01.04.20 |
| 131 | 1.2.4.21 | PINTURA CON ESMALTE SINTETICO | 18d | 2022-05-10 | 2022-05-31 | 130SS | 548d | 0d | 29,668.78 | 01.04.21 |
| 132 | 1.2.4.22 | NIVELACION Y COLOCACION CONTRAPISO C:A PROP. 1:4 e=2" | 18d | 2022-05-10 | 2022-05-31 | 131SS | 548d | 0d | 16,297.95 | 01.04.22 |
| 133 | 1.2.4.23 | ACERO FY=4200 KG/CM2, EN CONTRAPISO PARA NIVELACION DE LOSA | 18d | 2022-05-10 | 2022-05-31 | 132SS | 548d | 0d | 7,569.31 | 01.04.23 |
| 134 | 1.2.4.24 | LAVADERO DE UNA POZA ACABADO PULIDO INC./INSTALACIONES | 18d | 2022-05-10 | 2022-05-31 | 133SS | 548d |  | 2,080 | 01.04.24 |
| 135 | 1.2.4.25 | ELIMINACION DE MATERIAL EXCEDENTE A 2.00 KM DE DISTANCIA DE LA OBRA | 2d | 2022-03-15 | 2022-03-17 | 112 | 612d |  | 47,469.47 | 01.04.25 |

| ID | WBS | Task | Duration | Start | Finish | Predecessors | Total slack | Free slack | Cost | Text1 |
| --- | --- | --- | --- | --- | --- | --- | --- | --- | --- | --- |
| 136 | 1.2.5 | **EVACUACION Y SEÑALIZACION** | 3d | 2022-05-19 | 2022-05-23 |  | 555d |  | 2,495.8 | 01.05 |
| 137 | 1.2.5.1 | SUMINISTRO Y COLOCACION DE SEÑALIZACION ADOSADA A PARED DE 0.20x0.30m | 2d | 2022-05-19 | 2022-05-21 | 122 | 555d | 0d | 1,596 | 01.05.01 |
| 138 | 1.2.5.2 | SUMINISTRO Y COLOCACION DE SEÑALIZACION ADOSADA A PARED DE 0.30x0.40m | 2d | 2022-05-19 | 2022-05-21 | 137SS | 555d | 0d | 98.08 | 01.05.02 |
| 139 | 1.2.5.3 | SUMINISTRO E INSTALACION DE EXTINTORES | 1d | 2022-05-21 | 2022-05-23 | 138 | 555d |  | 801.72 | 01.05.03 |
| 140 | 1.2.6 | **INSTALACIONES SANITARIAS** | 49d | 2022-03-17 | 2022-05-13 |  | 548d |  | 33,145.58 | 01.06 |
| 141 | 1.2.6.1 | **APARATOS SANITARIOS Y ACCESORIOS** | 3d | 2022-05-10 | 2022-05-13 |  | 563d |  | 14,579.04 | 01.06.01 |
| 142 | 1.2.6.1.1 | SUMINISTRO DE APARATOS SANITARIO (INODORO) | 3d | 2022-05-10 | 2022-05-13 | 121SS | 563d | 0d | 10,848 | 01.06.01.01 |
| 143 | 1.2.6.1.2 | SUMINISTRO DE ACCESORIOS P/INODOROS | 3d | 2022-05-10 | 2022-05-13 | 142SS | 563d | 0d | 1,023.04 | 01.06.01.02 |
| 144 | 1.2.6.1.3 | INSTALACION DE APARATOS SANITARIOS Y ACCESORIOS | 3d | 2022-05-10 | 2022-05-13 | 143SS | 563d |  | 2,708 | 01.06.01.03 |
| 145 | 1.2.6.2 | **SISTEMA DE AGUA FRIA** | 4d | 2022-03-17 | 2022-03-22 |  | 548d |  | 1,743.6 | 01.06.02 |
| 146 | 1.2.6.2.1 | **SALIDA DE AGUA FRIA** | 4d | 2022-03-17 | 2022-03-22 |  | 548d |  | 1,743.6 | 01.06.02.01 |
| 147 | 1.2.6.2.1.1 | SALIDA DE AGUA FRIA Ø 1/2" BRONCE | 4d | 2022-03-17 | 2022-03-22 | 113 | 548d | 0d | 1,743.6 | 01.06.02.01.01 |
| 148 | 1.2.6.3 | **REDES DE DISTRIBUCION** | 4d | 2022-03-17 | 2022-03-22 |  | 548d |  | 636.04 | 01.06.03 |
| 149 | 1.2.6.3.1 | TUBERIA PVC CLASE 10 SP P/AGUA FRIA D=3/4" | 4d | 2022-03-17 | 2022-03-22 | 147SS | 548d | 0d | 636.04 | 01.06.03.01 |
| 150 | 1.2.6.4 | **REDES DE ALIMENTACION** | 4d | 2022-03-17 | 2022-03-22 |  | 548d |  | 1,599.17 | 01.06.04 |
| 151 | 1.2.6.4.1 | TUBERIA PVC CLASE 10 SP P/AGUA FRIA D=1" | 4d | 2022-03-17 | 2022-03-22 | 149SS | 548d | 0d | 1,599.17 | 01.06.04.01 |
| 152 | 1.2.6.5 | **ACCESORIOS DE REDES DE AGUA** | 4d | 2022-03-17 | 2022-03-22 |  | 548d |  | 3,672.12 | 01.06.05 |
| 153 | 1.2.6.5.1 | **ACCESORIOS EN REDES DE DISTRIBUCION Y ALIMENTACION** | 4d | 2022-03-17 | 2022-03-22 |  | 548d |  | 3,672.12 | 01.06.05.01 |
| 154 | 1.2.6.5.1.1 | SUMINISTRO E INSTALACION DE CODO DE 90° PVC AGUA C-10 1" | 4d | 2022-03-17 | 2022-03-22 | 151SS | 548d | 0d | 61.62 | 01.06.05.01.01 |
| 155 | 1.2.6.5.1.2 | SUMINISTRO E INSTALACION DE CODO DE 90° PVC AGUA C-10 3/4" | 4d | 2022-03-17 | 2022-03-22 | 154SS | 548d | 0d | 531.44 | 01.06.05.01.02 |
| 156 | 1.2.6.5.1.3 | SUMINISTRO E INSTALACION DE TEE PVC SAP DE Ø 1" | 4d | 2022-03-17 | 2022-03-22 | 155SS | 548d | 0d | 58.26 | 01.06.05.01.03 |
| 157 | 1.2.6.5.1.4 | SUMINISTRO E INSTALACION DE TEE PVC AGUA C-10 3/4" | 4d | 2022-03-17 | 2022-03-22 | 156SS | 548d | 0d | 404.8 | 01.06.05.01.04 |
| 158 | 1.2.6.5.1.5 | SUMINISTRO E INSTALACION DE CODO DE BRONCE 1/2" | 4d | 2022-03-17 | 2022-03-22 | 157SS | 548d | 0d | 449.76 | 01.06.05.01.05 |
| 159 | 1.2.6.5.1.6 | SUMINISTRO E INSTALACION DE ADAPTADOR PVC AGUA C-10 3/4" | 4d | 2022-03-17 | 2022-03-22 | 158SS | 548d | 0d | 386.4 | 01.06.05.01.06 |
| 160 | 1.2.6.5.1.7 | SUMINISTRO E INSTALACION DE NIPLE PVC AGUA C-10 3/4" | 4d | 2022-03-17 | 2022-03-22 | 159SS | 548d | 0d | 144.8 | 01.06.05.01.07 |
| 161 | 1.2.6.5.1.8 | SUMINISTRO E INSTALACION DE REDUCCION PVC AGUA C-10 1" A 3/4" | 4d | 2022-03-17 | 2022-03-22 | 160SS | 548d | 0d | 39.76 | 01.06.05.01.08 |
| 162 | 1.2.6.5.1.9 | SUMINISTRO E INSTALACION DE REDUCCION PVC AGUA C-10 3/4 A 1/2" | 4d | 2022-03-17 | 2022-03-22 | 161SS | 548d | 0d | 402.24 | 01.06.05.01.09 |
| 163 | 1.2.6.5.1.10 | SUMINISTRO E INSTALACION DE TUBO DE ABASTO PARA INODORO | 4d | 2022-03-17 | 2022-03-22 | 162SS | 548d | 0d | 949.76 | 01.06.05.01.10 |
| 164 | 1.2.6.5.1.11 | SUMINISTRO E INSTALACION DE TRAMPA PLASTICA C/REGISTRO | 4d | 2022-03-17 | 2022-03-22 | 163SS | 548d | 0d | 118.72 | 01.06.05.01.11 |
| 165 | 1.2.6.5.1.12 | SUMINISTRO E INSTALACION DE UNION UNIVERSAL PVC 3/4" | 4d | 2022-03-17 | 2022-03-22 | 164SS | 548d | 0d | 124.56 | 01.06.05.01.12 |

| ID | WBS | Task | Duration | Start | Finish | Predecessors | Total slack | Free slack | Cost | Text1 |
| --- | --- | --- | --- | --- | --- | --- | --- | --- | --- | --- |
| 166 | 1.2.6.6 | **VALVULAS** | 4d | 2022-03-17 | 2022-03-22 |  | 548d |  | 332.72 | 01.06.06 |
| 167 | 1.2.6.6.1 | VALVULA COMPUERTA PESADA DE BRONCE DE 3/4" | 4d | 2022-03-17 | 2022-03-22 | 165SS | 548d | 0d | 332.72 | 01.06.06.01 |
| 168 | 1.2.6.7 | **ALMACENAMIENTO DE AGUA** | 4d | 2022-03-17 | 2022-03-22 |  | 548d |  | 2,300 | 01.06.07 |
| 169 | 1.2.6.7.1 | MANTENIMIENTO Y/O ADECUACION DE CISTERNA EXISTENTE | 4d | 2022-03-17 | 2022-03-22 | 167SS | 548d | 0d | 800 | 01.06.07.01 |
| 170 | 1.2.6.7.2 | MANTENIMIENTO Y/O ADECUACION DE CISTERNA | 4d | 2022-03-17 | 2022-03-22 | 169SS | 548d | 0d | 1,500 | 01.06.07.02 |
| 171 | 1.2.6.8 | **DESAGUE Y VENTILACION** | 4d | 2022-03-22 | 2022-03-26 |  | 548d |  | 1,940.72 | 01.06.08 |
| 172 | 1.2.6.8.1 | SALIDAS DE DESAGUE DE PVC 4" | 4d | 2022-03-22 | 2022-03-26 | 170 | 548d | 0d | 1,627.2 | 01.06.08.01 |
| 173 | 1.2.6.8.2 | SALIDAS DE DESAGUE DE PVC 2" | 4d | 2022-03-22 | 2022-03-26 | 172SS | 548d | 0d | 313.52 | 01.06.08.02 |
| 174 | 1.2.6.9 | **REDES DE DERIVACION** | 4d | 2022-03-22 | 2022-03-26 |  | 548d |  | 901.78 | 01.06.09 |
| 175 | 1.2.6.9.1 | TUBO DE DESAGUE DE PVC Ø 4" | 4d | 2022-03-22 | 2022-03-26 | 173SS | 548d | 0d | 751.2 | 01.06.09.01 |
| 176 | 1.2.6.9.2 | TUBO DE DESAGUE DE PVC Ø 2" | 4d | 2022-03-22 | 2022-03-26 | 175SS | 548d | 0d | 150.58 | 01.06.09.02 |
| 177 | 1.2.6.10 | **REDES COLECTORAS** | 4d | 2022-03-22 | 2022-03-26 |  | 548d |  | 2,265.77 | 01.06.10 |
| 178 | 1.2.6.10.1 | TUBERIA DE DESAGUE PVC SAP D= 4" | 4d | 2022-03-22 | 2022-03-26 | 176SS | 548d | 0d | 2,265.77 | 01.06.10.01 |
| 179 | 1.2.6.11 | **ACCESORIOS DE REDES DE DESAGUE** | 4d | 2022-03-22 | 2022-03-26 |  | 548d |  | 1,413.84 | 01.06.11 |
| 180 | 1.2.6.11.1 | SUMINISTRO E INSTALACION DE CODO 90° PVC Ø 4" | 4d | 2022-03-22 | 2022-03-26 | 178SS | 548d | 0d | 357.12 | 01.06.11.01 |
| 181 | 1.2.6.11.2 | SUMINISTRO E INSTALACION DE CODO 90° PVC Ø 2" | 4d | 2022-03-22 | 2022-03-26 | 180SS | 548d | 0d | 103.44 | 01.06.11.02 |
| 182 | 1.2.6.11.3 | SUMINISTRO E INSTALACION DE REGISTRO DE BRONCE 4" | 4d | 2022-03-22 | 2022-03-26 | 181SS | 548d | 0d | 55.08 | 01.06.11.03 |
| 183 | 1.2.6.11.4 | SUMINISTRO Y COLOCACION DE SUMIDERO CON TRAMPA P | 4d | 2022-03-22 | 2022-03-26 | 182SS | 548d | 0d | 102.12 | 01.06.11.04 |
| 184 | 1.2.6.11.5 | SUMINISTRO E INSTALACIÓN DE YEE DE 4" A 2" | 4d | 2022-03-22 | 2022-03-26 | 183SS | 548d | 0d | 62.56 | 01.06.11.05 |
| 185 | 1.2.6.11.6 | SUMINISTRO E INSTALACIÓN DE YEE SIMPLE 4" | 4d | 2022-03-22 | 2022-03-26 | 184SS | 548d | 0d | 487.04 | 01.06.11.06 |
| 186 | 1.2.6.11.7 | SUMINISTRO E INSTALACIÓN DE SOMBRERO DE VENTILACION 2" | 4d | 2022-03-22 | 2022-03-26 | 185SS | 548d | 0d | 164.32 | 01.06.11.07 |
| 187 | 1.2.6.11.8 | SUMINISTRO E INSTALACIÓN DE SOMBRERO DE VENTILACION 2" | 4d | 2022-03-22 | 2022-03-26 | 186SS | 548d | 0d | 82.16 | 01.06.11.08 |
| 188 | 1.2.6.12 | **CAMARAS DE INSPECCION** | 4d | 2022-03-22 | 2022-03-26 |  | 548d |  | 1,760.78 | 01.06.12 |
| 189 | 1.2.6.12.1 | SUMINISTRO E INSTALACION DE CAJA DE REGISTRO | 4d | 2022-03-22 | 2022-03-26 | 187SS | 548d | 0d | 1,760.78 | 01.06.12.01 |

| ID | WBS | Task | Duration | Start | Finish | Predecessors | Total slack | Free slack | Cost | Text1 |
| --- | --- | --- | --- | --- | --- | --- | --- | --- | --- | --- |
| 190 | 1.2.7 | **ELECTRICAS** | 8d | 2022-05-16 | 2022-05-25 |  | 553d |  | 18,051.99 | 01.07 |
| 191 | 1.2.7.1 | INSTALACIONES ELECTRIICAS EN AULAS PROVISIONALES | 8d | 2022-05-16 | 2022-05-25 | 123 | 553d |  | 18,051.99 | 01.07.01 |
| 192 | 1.3 | **ESTRUCTURAS** | 600d | 2022-03-01 | 2024-01-30 |  | 7d |  | 13,487,290.96 | 02 |
| 193 | 1.3.1 | **PLAN DE MANEJO AMBIENTAL** | 600d | 2022-03-01 | 2024-01-30 |  | 26d |  | 183,539.56 | 02.01 |
| 194 | 1.3.1.1 | PLAN DE MANEJO AMBIENTAL | 600d | 2022-03-01 | 2024-01-30 | 108SS | 26d |  | 183,539.56 | 02.01.01 |
| 195 | 1.3.2 | **MOVIMIENTO DE TIERRAS** | 438d | 2022-03-09 | 2023-08-02 |  | 0d |  | 1,217,072.73 | 02.02 |
| 196 | 1.3.2.1 | CORTE DE TERRENO NATURAL CON MAQUINARIA | 14d | 2022-03-09 | 2022-03-25 | 11SS | 0d |  | 20,028.59 | 02.02.01 |
| 197 | 1.3.2.2 | PERFILADO, NIVELACION Y COMPACTACION DE TERRENO NATURAL CON (MAQUINARIA) | 14d | 2022-03-09 | 2022-03-25 | 196SS | 0d |  | 66,413.89 | 02.02.02 |
| 198 | 1.3.2.3 | PERFILADO, NIVELACION Y COMPACTACION DE TERRENO NATURAL - MANUAL | 86d | 2022-03-14 | 2022-06-22 | 199SS | 529d |  | 41,584.07 | 02.02.03 |
| 199 | 1.3.2.4 | EXCAVACION MANUAL DE ZANJAS P/CIMIENTOS, ZAPATAS Y PISOS | 86d | 2022-03-14 | 2022-06-22 | 197FS-10d | 0d |  | 297,195.21 | 02.02.04 |
| 200 | 1.3.2.5 | MEJORAMIENTO CON MATERIAL DE PRESTAMO - ROCA MEDIANA DE 6" - 8" LLENAR VACIOS CON HORMIGON | 40d | 2022-05-18 | 2022-07-04 | 199FS-30d | 0d |  | 148,287.46 | 02.02.05 |
| 201 | 1.3.2.6 | COLOCACION, COMPACTACION Y NIVELACION DE CAPA DE HORMIGON (CON EQUIPO LIVIANO) | 25d | 2023-06-08 | 2023-07-07 | 249 | 23d | 0d | 142,505.42 | 02.02.06 |
| 202 | 1.3.2.7 | COLOCACION, COMPACTACION Y NIVELACION DE RELLENO CON MATERIAL PROPIO (CON EQUIPO LIVIANO) | 25d | 2022-10-26 | 2022-11-24 | 224 | 396d |  | 108,711.72 | 02.02.07 |
| 203 | 1.3.2.8 | COLOCACION, COMPACTACION Y NIVELACION DE CAPA DE AFIRMADO (CON EQUIPO LIVIANO) e=0.15m | 25d | 2023-06-14 | 2023-07-13 | 201FS-20d | 181d | 0d | 119,541.1 | 02.02.08 |
| 204 | 1.3.2.9 | CAPA DE MATERIAL DE PRESTAMO - HORMIGON GRUESO e=0.20m CON EQUIPO PESADO | 5d | 2023-07-20 | 2023-07-26 | 207 | 181d | 0d | 102,095.33 | 02.02.09 |
| 205 | 1.3.2.10 | COLCOACION, NIVELACION DE CAPA DE ARENA FINA e=0.05m, CON EQUIPO PESADO | 2d | 2023-07-28 | 2023-07-31 | 206 | 181d | 0d | 20,331 | 02.02.10 |
| 206 | 1.3.2.11 | COLCOACION , NIVELACION DE CAPA DE ARENA GRUESA e=0.05m, CON EQUIPO PESADO | 2d | 2023-07-26 | 2023-07-28 | 204 | 181d | 0d | 17,901 | 02.02.11 |
| 207 | 1.3.2.12 | COLCOACION, NIVELACION DE CAPA DE ARENA FINA e=0.05m, PARA PISO DE ADOQUIN | 12d | 2023-07-06 | 2023-07-20 | 203FS-6d | 181d | 0d | 6,877.96 | 02.02.12 |
| 208 | 1.3.2.13 | CAPA DE MATERIAL DE PRESTAMO - AFIRMADO e=0.20m CON EQUIPO PESADO | 2d | 2023-07-31 | 2023-08-02 | 205 | 181d |  | 33,884.37 | 02.02.13 |
| 209 | 1.3.2.14 | ELIMINACION DE MATERIAL EXCEDENTE A 2.00 KM DE DISTANCIA DE LA OBRA | 10d | 2022-06-22 | 2022-07-04 | 199 | 519d |  | 91,715.61 | 02.02.14 |
| 210 | 1.3.3 | **OBRAS DE CONCRETO SIMPLE** | 398d | 2022-06-22 | 2023-09-29 |  | 0d |  | 267,427.79 | 02.03 |
| 211 | 1.3.3.1 | FALSO PISO PROP 1:8 C:H | 20d | 2023-09-06 | 2023-09-29 | 303SS+10d | 131d |  | 49,261.46 | 02.03.01 |
| 212 | 1.3.3.2 | SOLADO PROP. 1:8, e=0.10m | 19d | 2022-06-22 | 2022-07-14 | 200FS-10d | 0d |  | 99,892.57 | 02.03.02 |
| 213 | 1.3.3.3 | CIMIENTO DE CONCRETO CICLOPEO PROP. 1:8 + 25% P.M. | 2d | 2022-09-19 | 2022-09-21 | 220SS+2d | 431d | 0d | 5,981.66 | 02.03.03 |
| 214 | 1.3.3.4 | CIMIENTO DE CONCRETO CICLOPEO PROP. 1:10 + 30% P.G. | 20d | 2022-09-21 | 2022-10-14 | 213 | 431d |  | 112,292.1 | 02.03.04 |

| ID | WBS | Task | Duration | Start | Finish | Predecessors | Total slack | Cost | Text1 |
| --- | --- | --- | --- | --- | --- | --- | --- | --- | --- |
| 215 | 1.3.4 | **OBRAS DE CONCRETO ARMADO** | 383d | 2022-07-02 | 2023-09-22 |  | 0d | 11,080,865.97 | 02.04 |
| 216 | 1.3.4.1 | **ZAPATAS** | 55d | 2022-07-02 | 2022-09-05 |  | 0d | 1,388,378.62 | 02.04.01 |
| 217 | 1.3.4.1.1 | CONCRETO F'C=280 KG/CM2 - PARA ZAPATAS | 30d | 2022-08-01 | 2022-09-05 | 218FS-20d | 0d | 575,660.79 | 02.04.01.01 |
| 218 | 1.3.4.1.2 | ACERO CORRUGADO FY=4200 KG/CM2 GRADO 60 - PARA ZAPATAS | 45d | 2022-07-02 | 2022-08-24 | 212FS-10d | 0d | 812,717.83 | 02.04.01.02 |
| 219 | 1.3.4.2 | **VIGA DE CIMENTACION** | 33d | 2022-08-18 | 2022-09-26 |  | 0d | 251,506.66 | 02.04.02 |
| 220 | 1.3.4.2.1 | CONCRETO F'C=280 KG/CM2 - EN VIGAS DE CIMENTACION | 8d | 2022-09-16 | 2022-09-26 | 222FS-4d | 0d | 62,293.71 | 02.04.02.01 |
| 221 | 1.3.4.2.2 | ACERO CORRUGADO FY=4200 KG/CM2 GRADO 60 - VIGA DE CIMENTACION | 22d | 2022-08-18 | 2022-09-13 | 217FS-15d | 0d | 152,529.32 | 02.04.02.02 |
| 222 | 1.3.4.2.3 | ENCOFRADO Y DESENCOFRADO DE VIGA DE CIMENTACION | 22d | 2022-08-26 | 2022-09-21 | 221FS-15d | 0d | 36,683.63 | 02.04.02.03 |
| 223 | 1.3.4.3 | **SOBRECIMIENTO ARMADO** | 32d | 2022-09-19 | 2022-10-26 |  | 0d | 352,648.84 | 02.04.03 |
| 224 | 1.3.4.3.1 | CONCRETO F'C=175 KG/CM2 - PARA SOBRECIMIENTO ARMADO | 12d | 2022-10-12 | 2022-10-26 | 226FS-8d | 0d | 100,353.34 | 02.04.03.01 |
| 225 | 1.3.4.3.2 | ACERO CORRUGADO FY=4200 KG/CM2 GRADO 60 - PARA SOBRECIMIENTO ARMADO | 24d | 2022-09-19 | 2022-10-17 | 220SS+2d | 0d | 100,180.69 | 02.04.03.02 |
| 226 | 1.3.4.3.3 | ENCOFRADO Y DESENCOFRADO DE SOBRECIMIENTO | 24d | 2022-09-23 | 2022-10-21 | 225FS-20d | 0d | 152,114.81 | 02.04.03.03 |
| 227 | 1.3.4.4 | **COLUMNAS Y PLACAS** | 115d | 2022-10-12 | 2023-02-23 |  | 0d | 3,912,638.48 | 02.04.04 |
| 228 | 1.3.4.4.1 | CONCRETO F'C=210 KG/CM2 PARA COLUMNAS | 40d | 2023-01-07 | 2023-02-23 | 230FS-30d | 0d | 869,015.75 | 02.04.04.01 |
| 229 | 1.3.4.4.2 | ACERO CORRUGADO FY=4200 KG/CM2 GRADO 60 PARA COLUMNA Y PLACAS | 85d | 2022-10-12 | 2023-01-19 | 224SS | 0d | 2,001,921.95 | 02.04.04.02 |
| 230 | 1.3.4.4.3 | ENCOFRADO Y DESENCOFRADO DE COLUMNA Y PLACAS | 90d | 2022-10-29 | 2023-02-11 | 229FS-70d | 0d | 1,041,700.78 | 02.04.04.03 |
| 231 | 1.3.4.5 | **COLUMNETAS** | 43d | 2023-06-26 | 2023-08-15 |  | 0d | 548,465.43 | 02.04.05 |
| 232 | 1.3.4.5.1 | CONCRETO F'C=175 KG/CM2 EN COLUMNETAS | 18d | 2023-07-25 | 2023-08-15 | 234FS-5d | 0d | 77,329.73 | 02.04.05.01 |
| 233 | 1.3.4.5.2 | ACERO CORRUGADO FY=4200 KG/CM2 GRADO 60 - PARA COLUMNETAS | 30d | 2023-06-26 | 2023-07-31 | 284FS-20d | 0d | 329,365.66 | 02.04.05.02 |
| 234 | 1.3.4.5.3 | ENCOFRADO Y DESENCOFRADO DE COLUMNETAS | 30d | 2023-06-26 | 2023-07-31 | 233SS | 0d | 141,770.04 | 02.04.05.03 |
| 235 | 1.3.4.6 | **VIGAS** | 120d | 2023-01-19 | 2023-06-08 |  | 0d | 2,225,689.55 | 02.04.06 |
| 236 | 1.3.4.6.1 | CONCRETO F'C= 210 KG/CM2 EN VIGAS | 60d | 2023-03-30 | 2023-06-08 | 245FS-50d | 0d | 512,556.1 | 02.04.06.01 |
| 237 | 1.3.4.6.2 | ACERO CORRUGADO FY=4200 KG/CM2 GRADO 60 - PARA VIGAS | 110d | 2023-01-19 | 2023-05-27 | 247SS | 0d | 1,162,508.28 | 02.04.06.02 |
| 238 | 1.3.4.6.3 | ENCOFRADO Y DESENCOFRADO DE VIGAS | 110d | 2023-01-19 | 2023-05-27 | 228FS-30d | 0d | 550,625.17 | 02.04.06.03 |

| ID | WBS | Task | Duration | Start | Finish | Predecessors | Total slack | Free slack | Cost | Text1 |
| --- | --- | --- | --- | --- | --- | --- | --- | --- | --- | --- |
| 239 | 1.3.4.7 | **VIGAS DE CIERRE EN MUROS** | 38d | 2023-07-28 | 2023-09-11 |  | 0d |  | 366,101.05 | 02.04.07 |
| 240 | 1.3.4.7.1 | CONCRETO F'C= 175KG/CM2 EN VIGAS DE CIERRE | 16d | 2023-08-23 | 2023-09-11 | 242FS-8d | 0d |  | 67,763.78 | 02.04.07.01 |
| 241 | 1.3.4.7.2 | ACERO CORRUGADO FY=4200 KG/CM2 GRADO 60 - VIGA DE CIERRE | 30d | 2023-08-03 | 2023-09-07 | 232FS-10d | 0d |  | 167,879.81 | 02.04.07.02 |
| 242 | 1.3.4.7.3 | ENCOFRADO Y DESENCOFRADO DE VIGAS DE CIERRE | 30d | 2023-07-28 | 2023-09-01 | 241FS-35d | 0d |  | 130,457.46 | 02.04.07.03 |
| 243 | 1.3.4.8 | **LOSA ALIGERADA** | 120d | 2023-01-19 | 2023-06-08 |  | 0d |  | 1,432,664.65 | 02.04.08 |
| 244 | 1.3.4.8.1 | CONCRETO F'C=210 KG/CM2 EN LOSA ALIGERADA | 60d | 2023-03-30 | 2023-06-08 | 236SS | 0d |  | 283,733.53 | 02.04.08.01 |
| 245 | 1.3.4.8.2 | ACERO CORRUGADO FY=4200 KG/CM2 GRADO 60 - PARA LOSAS ALIGERADAS | 110d | 2023-01-19 | 2023-05-27 | 237SS | 0d |  | 341,293.53 | 02.04.08.02 |
| 246 | 1.3.4.8.3 | ENCOFRADO Y DESENCOFRADO DE LOSA ALIGERADA | 110d | 2023-01-19 | 2023-05-27 | 238SS | 0d |  | 564,154.61 | 02.04.08.03 |
| 247 | 1.3.4.8.4 | LADRILLO DE TECHO 15x30x30 - LOSA ALIGERADA | 110d | 2023-01-19 | 2023-05-27 | 246SS | 0d |  | 243,482.98 | 02.04.08.04 |
| 248 | 1.3.4.9 | **LOSA MACIZA** | 120d | 2023-01-19 | 2023-06-08 |  | 60d |  | 209,149.3 | 02.04.09 |
| 249 | 1.3.4.9.1 | CONCRETO F'C=210 KG/CM2 PARA LOSA MACIZA | 60d | 2023-03-30 | 2023-06-08 | 244SS | 0d |  | 42,193.36 | 02.04.09.01 |
| 250 | 1.3.4.9.2 | ACERO CORRUGADO FY=4200 KG/CM2 GRADO 60 - LOSA MACIZA | 110d | 2023-01-19 | 2023-05-27 | 245SS | 238d |  | 112,164.83 | 02.04.09.02 |
| 251 | 1.3.4.9.3 | ENCOFRADO Y DESENCOFRADO DE LOSA MACIZA | 110d | 2023-01-19 | 2023-05-27 | 246SS | 238d |  | 54,791.11 | 02.04.09.03 |
| 252 | 1.3.4.10 | **ESCALERA** | 32d | 2023-06-08 | 2023-07-15 |  | 122d |  | 130,453.37 | 02.04.10 |
| 253 | 1.3.4.10.1 | CONCRETO F'C=210 KG/CM2 EN ESCALERA | 7d | 2023-07-07 | 2023-07-15 | 254 | 122d | 0d | 39,030.78 | 02.04.10.01 |
| 254 | 1.3.4.10.2 | ACERO DE REFUERZO F'Y=4,200 KG/CM2 GRADO 60 PARA ESCALERA | 15d | 2023-06-20 | 2023-07-07 | 255FS-10d | 122d | 0d | 50,680.63 | 02.04.10.02 |
| 255 | 1.3.4.10.3 | ENCOFRADO Y DESENCOFRADO DE ESCALERA | 20d | 2023-06-08 | 2023-07-01 | 269SS+5d | 122d | 0d | 40,741.96 | 02.04.10.03 |
| 256 | 1.3.4.11 | **RAMPA** | 22d | 2023-07-13 | 2023-08-08 |  | 122d |  | 57,387.19 | 02.04.11 |
| 257 | 1.3.4.11.1 | CONCRETO F'C=210 KG/CM2 EN RAMPA | 4d | 2023-08-03 | 2023-08-08 | 259 | 122d | 0d | 15,252.73 | 02.04.11.01 |
| 258 | 1.3.4.11.2 | ACERO CORRUGADO FY=4200 KG/CM2 GRADO 60 - PARA RAMPA | 12d | 2023-07-13 | 2023-07-27 | 253FS-2d | 122d | 0d | 29,321.73 | 02.04.11.02 |
| 259 | 1.3.4.11.3 | ENCOFRADO Y DESENCOFRADO DE RAMPA | 12d | 2023-07-20 | 2023-08-03 | 258FS-6d | 122d | 0d | 12,812.73 | 02.04.11.03 |
| 260 | 1.3.4.12 | **GRADERIAS EN TRIBUNAS** | 29d | 2023-08-03 | 2023-09-06 |  | 122d |  | 102,894.82 | 02.04.12 |
| 261 | 1.3.4.12.1 | CONCRETO F'C=210 KG/CM2 EN GRADERIAS DE TRIBUNAS | 6d | 2023-08-30 | 2023-09-06 | 263FS-4d | 122d | 0d | 20,826.29 | 02.04.12.01 |
| 262 | 1.3.4.12.2 | ACERO CORRUGADO FY=4200 KG/CM2 GRADO 60 - EN GRADERIAS DE TRIBUNAS | 25d | 2023-08-03 | 2023-09-01 | 257SS | 122d | 0d | 62,079.78 | 02.04.12.02 |
| 263 | 1.3.4.12.3 | ENCOFRADO Y DESENCOFRADO EN GRADERIAS DE TRIBUNAS | 25d | 2023-08-05 | 2023-09-04 | 262SS+2d | 122d | 0d | 19,988.75 | 02.04.12.03 |

| ID | WBS | Task | Duration | Start | Finish | Predecessors | Total slack | Free slack | Cost | Text1 |
| --- | --- | --- | --- | --- | --- | --- | --- | --- | --- | --- |
| 264 | 1.3.4.13 | **CISTERNA** | 14d | 2023-09-06 | 2023-09-22 |  | 122d |  | 102,888.01 | 02.04.13 |
| 265 | 1.3.4.13.1 | CONCRETO F'C=210 KG/CM2 EN CISTERNA | 2d | 2023-09-20 | 2023-09-22 | 267 | 122d | 0d | 27,343.05 | 02.04.13.01 |
| 266 | 1.3.4.13.2 | ACERO CORRUGADO FY=4200 KG/CM2 GRADO 60 - PARA CISTERNA | 6d | 2023-09-06 | 2023-09-13 | 261 | 122d | 0d | 62,079.78 | 02.04.13.02 |
| 267 | 1.3.4.13.3 | ENCOFRADO Y DESENCOFRADO PARA CISTERNA | 6d | 2023-09-13 | 2023-09-20 | 266 | 122d | 0d | 13,465.18 | 02.04.13.03 |
| 268 | 1.3.5 | **COBERTURAS LIVIANAS** | 40d | 2023-06-02 | 2023-07-19 |  | 0d |  | 562,309.06 | 02.05 |
| 269 | 1.3.5.1 | SUMINISTRO Y COLOCACION DE TIJERAL METALICO CURVO TIPO 1 LONG=27.80M | 40d | 2023-06-02 | 2023-07-19 | 292FS-40d | 0d |  | 78,881.52 | 02.05.01 |
| 270 | 1.3.5.2 | SUMINISTRO Y COLOCACION DE TIJERAL METALICO TRIANGULAR TIPO 2 LONG=7.95M | 40d | 2023-06-02 | 2023-07-19 | 269SS | 0d |  | 37,732.32 | 02.05.02 |
| 271 | 1.3.5.3 | SUMINISTRO Y COLOCACION DE VIGUETA METALICA TIPO VG-C | 40d | 2023-06-02 | 2023-07-19 | 270SS | 0d |  | 121,857.43 | 02.05.03 |
| 272 | 1.3.5.4 | SUMINISTRO Y COLOCACION DE VIGUETA METALICA TUB. RECT. 2" x3" x 2.00mm | 40d | 2023-06-02 | 2023-07-19 | 271SS | 0d |  | 33,180.84 | 02.05.04 |
| 273 | 1.3.5.5 | SUMINISTRO Y COLOCACION DE TEMPLADOR DE Ø 5/8" | 40d | 2023-06-02 | 2023-07-19 | 272SS | 0d |  | 8,344.8 | 02.05.05 |
| 274 | 1.3.5.6 | SUMINISTRO Y COLOCACION DE TEMPLADOR DE Ø 3/8" | 40d | 2023-06-02 | 2023-07-19 | 273SS | 0d |  | 3,965.5 | 02.05.06 |
| 275 | 1.3.5.7 | SUMINISTRO Y COLOCACION DE TENSORES DE FIERRO LISO Ø 1" | 40d | 2023-06-02 | 2023-07-19 | 274SS | 0d |  | 11,262 | 02.05.07 |
| 276 | 1.3.5.8 | SUMINISTRO Y COLOCACION DE TENSORES DE FIERRO LISO Ø 3/4" | 40d | 2023-06-02 | 2023-07-19 | 275SS | 0d |  | 2,809.3 | 02.05.08 |
| 277 | 1.3.5.9 | SUMINISTRO Y COLOCACION DE COLGANTE DE FIERRO LISO Ø 1/2" | 40d | 2023-06-02 | 2023-07-19 | 276SS | 0d |  | 1,940.4 | 02.05.09 |
| 278 | 1.3.5.10 | SUMINISTRO Y COLOCACION DE COBERTURA DE ACERO ALUMINIZADO (CALAMINON CU e=0.50m) | 40d | 2023-06-02 | 2023-07-19 | 277SS | 0d |  | 185,055.36 | 02.05.10 |
| 279 | 1.3.5.11 | SUMINISTRO Y COLOCACION DE COBERTURA DE ACERO ALUMINIZADO (CALAMINON TI e=0.40m) | 40d | 2023-06-02 | 2023-07-19 | 278SS | 0d |  | 32,292.76 | 02.05.11 |
| 280 | 1.3.5.12 | SUMINISTRO Y COLOCACION DE APOYOS FIJOS ENTRE COLUMNA Y TIJERAL PARABOLICO | 40d | 2023-06-02 | 2023-07-19 | 279SS | 0d |  | 4,266 | 02.05.12 |
| 281 | 1.3.5.13 | SUMINISTRO Y COLOCACION DE APOYOS MOVIL ENTRE COLUMNA Y TIJERAL PARABOLICO | 40d | 2023-06-02 | 2023-07-19 | 280SS | 0d |  | 5,800.08 | 02.05.13 |
| 282 | 1.3.5.14 | SUMINISTRO Y COLOCACION DE ARRIOSTRE DE FIERRO CORRUGADO Ø 3/8" | 40d | 2023-06-02 | 2023-07-19 | 281SS | 0d |  | 12,230.4 | 02.05.14 |
| 283 | 1.3.5.15 | SUMINISTRO Y COLOCACION DE CANALETA DE PLANCHA GALVANIZADA 2mm (0.10x0.20x0.15m) | 40d | 2023-06-02 | 2023-07-19 | 282SS | 0d |  | 19,882.28 | 02.05.15 |
| 284 | 1.3.5.16 | SUMINISTRO Y COLOCACION DE BAJADA DE MONTANTE DE TUBERIA PVC Ø 3" | 40d | 2023-06-02 | 2023-07-19 | 283SS | 0d |  | 2,808.07 | 02.05.16 |
| 285 | 1.3.6 | **OTROS** | 380d | 2022-08-18 | 2023-11-04 |  | 100d |  | 176,075.85 | 02.06 |
| 286 | 1.3.6.1 | JUNTAS DE DILATACION ASFALTICA e=1" EN CERCO PERIMETRICO | 4d | 2023-10-05 | 2023-10-10 | 287 | 122d |  | 5,340.72 | 02.06.01 |
| 287 | 1.3.6.2 | TARRAJEO DE CISTERNA Y TANQUE ELEVADO PROP. 1:4, e=1.50cm, CON ADITIVO IMPERMEABILIZANTE | 8d | 2023-09-26 | 2023-10-05 | 265SS+5d | 122d | 0d | 11,079.35 | 02.06.02 |
| 288 | 1.3.6.3 | CURADO DE ESTRUCTURAS DE CONCRETO CON ADITIVO | 380d | 2022-08-18 | 2023-11-04 | 219SS | 100d |  | 159,134.82 | 02.06.03 |
| 289 | 1.3.6.4 | COLOCACION DE CINTA WATER STOP 6" - CAUCHO NATURAL | 1d | 2023-09-20 | 2023-09-21 | 265SS | 138d |  | 520.96 | 02.06.04 |

| ID | WBS | Task | Duration | Start | Finish | Predecessors | Total slack | Free slack | Cost | Text1 |
| --- | --- | --- | --- | --- | --- | --- | --- | --- | --- | --- |
| 290 | 1.4 | **ARQUITECTURA** | 358d | 2023-01-07 | 2024-02-29 |  | 0d |  | 7,133,196.15 | 03 |
| 291 | 1.4.1 | **MUROS Y TABIQUES** | 75d | 2023-04-22 | 2023-07-19 |  | 0d |  | 683,835.87 | 03.01 |
| 292 | 1.4.1.1 | MURO DE LADRILLO TIPO IV (12.5x9x23) APAREJO DE SOGA | 75d | 2023-04-22 | 2023-07-19 | 249FS-40d | 0d |  | 680,685.39 | 03.01.01 |
| 293 | 1.4.1.2 | MURO DE LADRILLO TIPO IV (12.5x9x23) APAREJO DE CABEZA | 75d | 2023-04-22 | 2023-07-19 | 292SS | 193d |  | 3,150.48 | 03.01.02 |
| 294 | 1.4.2 | **REVOQUES Y ENLUCIDOS** | 60d | 2023-08-25 | 2023-11-03 |  | 0d |  | 1,711,840.8 | 03.02 |
| 295 | 1.4.2.1 | TARRAJEO EN MUROS EXTERIORES CA 1:4, e=1.5cm, CEMENTO TIPO ICO | 60d | 2023-08-25 | 2023-11-03 | 240SS+2d | 0d |  | 403,186.35 | 03.02.01 |
| 296 | 1.4.2.2 | TARRAJEO EN MUROS INTERIORES CA 1:4, e=1.5cm, CEMENTO TIPO ICO | 60d | 2023-08-25 | 2023-11-03 | 295SS | 0d |  | 135,578.7 | 03.02.02 |
| 297 | 1.4.2.3 | TARRAJEO EN COLUMNAS PROP. 1:5 e=1.5cm, CEMENTO TIPO ICO | 60d | 2023-08-25 | 2023-11-03 | 296SS | 0d |  | 376,086.47 | 03.02.03 |
| 298 | 1.4.2.4 | TARRAJEO EN CIELO RASO PROP. 1:5, e=1.5cm, CEMENTO TIPO ICO | 60d | 2023-08-25 | 2023-11-03 | 297SS | 0d |  | 449,784.08 | 03.02.04 |
| 299 | 1.4.2.5 | TARRAJEO DE VIGAS PROP. 1:4, e=1.5cm, CEMENTO TIPO ICO | 60d | 2023-08-25 | 2023-11-03 | 298SS | 0d |  | 242,789.82 | 03.02.05 |
| 300 | 1.4.2.6 | TARRAJEO DE RAYADO PRIMARIO MEZCLA 1:4 | 60d | 2023-08-25 | 2023-11-03 | 299SS | 0d |  | 28,771.32 | 03.02.06 |
| 301 | 1.4.2.7 | TARRAJEO DE SOBRECIMIENTO PROP. 1:4 e=1.5cm CEMENTO TIPO ICO | 60d | 2023-08-25 | 2023-11-03 | 300SS | 0d |  | 10,361.75 | 03.02.07 |
| 302 | 1.4.2.8 | REVESTIMIENTO DE DERRAMES h=0.15m, PROP. 1:4, e=1.5cm, CEMENTO TIPO ICO | 60d | 2023-08-25 | 2023-11-03 | 301SS | 0d |  | 35,038.57 | 03.02.08 |
| 303 | 1.4.2.9 | TARRAJEO DE GRADERIAS ACABADO SEMI-PULIDO e=1.5cm CEMENTO TIPO ICO INC. BRUÑADO | 60d | 2023-08-25 | 2023-11-03 | 302SS | 0d |  | 30,243.74 | 03.02.09 |
| 304 | 1.4.3 | **PINTURA** | 45d | 2023-11-30 | 2024-01-22 |  | 0d |  | 724,263 | 03.03 |
| 305 | 1.4.3.1 | PINTURA LATEX SATINADA EN MUROS EXTERIORES | 45d | 2023-11-30 | 2024-01-22 | 388FS-22d | 0d |  | 154,950.38 | 03.03.01 |
| 306 | 1.4.3.2 | PINTURA LATEX SATINADA EN MUROS INTERIORES | 45d | 2023-11-30 | 2024-01-22 | 305SS | 19d | 0d | 74,017.09 | 03.03.02 |
| 307 | 1.4.3.3 | PINTURA LATEX SATINADA EN COLUMNAS | 45d | 2023-11-30 | 2024-01-22 | 306SS | 19d | 0d | 196,745.64 | 03.03.03 |
| 308 | 1.4.3.4 | PINTURA LATEX SATINADA EN CIELO RASO | 45d | 2023-11-30 | 2024-01-22 | 307SS | 19d | 0d | 162,724.47 | 03.03.04 |
| 309 | 1.4.3.5 | PINTURA LATEX SATINADA EN VIGAS | 45d | 2023-11-30 | 2024-01-22 | 308SS | 19d | 0d | 107,396.5 | 03.03.05 |
| 310 | 1.4.3.6 | PINTURA LATEX SATINADA EN DERRAMES | 45d | 2023-11-30 | 2024-01-22 | 309SS | 19d | 0d | 7,464.66 | 03.03.06 |
| 311 | 1.4.3.7 | PINTURA ESMALTE SINTETICO a=5cm | 45d | 2023-11-30 | 2024-01-22 | 310SS | 19d | 0d | 1,614.45 | 03.03.07 |
| 312 | 1.4.3.8 | PINTURA ESMALTE EN CONTRAZOCALO DE CEMENTO h=0.30m | 45d | 2023-11-30 | 2024-01-22 | 311SS | 19d | 0d | 6,486.94 | 03.03.08 |
| 313 | 1.4.3.9 | PINTURA ESMALTE EN CONTRAZOCALO DE CEMENTO h=0.10m | 45d | 2023-11-30 | 2024-01-22 | 312SS | 19d | 0d | 7,674.01 | 03.03.09 |
| 314 | 1.4.3.10 | PINTURA ESMALTE EN CONTRA PASO DE TRIBUNA h=0.40m | 45d | 2023-11-30 | 2024-01-22 | 313SS | 19d | 0d | 5,188.86 | 03.03.10 |

| ID | WBS | Task | Duration | Start | Finish | Predecessors | Total slack | Cost | Text1 |
| --- | --- | --- | --- | --- | --- | --- | --- | --- | --- |
| 315 | 1.4.4 | **PISOS Y PAVIMENTOS** | 65d | 2023-09-18 | 2023-12-02 |  | 0d | 1,297,120.41 | 03.04 |
| 316 | 1.4.4.1 | CONTRAPISO C:A PROP. 1:4, e=2.5cm | 20d | 2023-09-18 | 2023-10-11 | 303FS-40d | 0d | 168,231.87 | 03.04.01 |
| 317 | 1.4.4.2 | PISO CERAMICO 0.30 x 0.30 ANTIDESLIZANTE, ALTO TRANSITO | 60d | 2023-09-23 | 2023-12-02 | 316SS+5d | 0d | 265,069.13 | 03.04.02 |
| 318 | 1.4.4.3 | ENCHAPE CERAMICO (0.30x0.30) | 60d | 2023-09-23 | 2023-12-02 | 317SS | 0d | 9,283.56 | 03.04.03 |
| 319 | 1.4.4.4 | CONCRETO EN VEREDAS F'C=175 KG/CM2, e=10cm, ACABADO FROTACHADO FINO Y BRUÑADO | 60d | 2023-09-23 | 2023-12-02 | 318SS | 0d | 157,983.79 | 03.04.04 |
| 320 | 1.4.4.5 | PISO CEMENTO FROTACHADO FINO Y BRUÑADO | 60d | 2023-09-23 | 2023-12-02 | 319SS | 0d | 122,233.74 | 03.04.05 |
| 321 | 1.4.4.6 | PISO DE ADOQUIN DE CONCRETO h=4cm | 60d | 2023-09-23 | 2023-12-02 | 320SS | 0d | 59,562.26 | 03.04.06 |
| 322 | 1.4.4.7 | LOSA DEPORTIVA DE C° F'C=175 KG/CM2, e=0.15m INC. ENCOFRADO Y DESENCOFRADO | 60d | 2023-09-23 | 2023-12-02 | 321SS | 0d | 251,411.44 | 03.04.07 |
| 323 | 1.4.4.8 | CONCRETO EN LOSAS F'C=210 KG/CM2, e=20cm INCLUYE ENCOFRADO Y DESENCOFRADO | 60d | 2023-09-23 | 2023-12-02 | 322SS | 0d | 35,199.57 | 03.04.08 |
| 324 | 1.4.4.9 | CORTE EN FALSO PISO | 60d | 2023-09-23 | 2023-12-02 | 323SS | 0d | 784.76 | 03.04.09 |
| 325 | 1.4.4.10 | CORTE EN CONTRAPISO | 60d | 2023-09-23 | 2023-12-02 | 324SS | 0d | 560.29 | 03.04.10 |
| 326 | 1.4.4.11 | SUMINISTRO E INSTALACION DE PISO DE POLIURETANO | 60d | 2023-09-23 | 2023-12-02 | 325SS | 0d | 226,800 | 03.04.11 |
| 327 | 1.4.5 | **ZOCALOS Y CONTRAZOCALOS** | 60d | 2023-09-23 | 2023-12-02 |  | 0d | 132,432.79 | 03.05 |
| 328 | 1.4.5.1 | ZOCALO DE CERAMICO 0.30 x 0.30m | 60d | 2023-09-23 | 2023-12-02 | 326SS | 0d | 57,338.86 | 03.05.01 |
| 329 | 1.4.5.2 | CONTRA ZOCALO DE CERAMICA e=0.10m | 60d | 2023-09-23 | 2023-12-02 | 328SS | 0d | 24,271.29 | 03.05.02 |
| 330 | 1.4.5.3 | CONTRA ZOCALO DE CEMENTO H= 0.30m e=1.5cm | 60d | 2023-09-23 | 2023-12-02 | 329SS | 0d | 15,660.2 | 03.05.03 |
| 331 | 1.4.5.4 | CONTRA ZOCALO DE CEMENTO H= 0.10m e=1.5cm | 60d | 2023-09-23 | 2023-12-02 | 330SS | 0d | 35,162.44 | 03.05.04 |
| 332 | 1.4.6 | **CARPINTERIA DE MADERA** | 30d | 2023-11-09 | 2023-12-14 |  | 0d | 361,497.76 | 03.06 |
| 333 | 1.4.6.1 | SUMINISTRO Y COLOCACION DE PUERTAS DE MADERA CEDRO MACHIEMMBRADA (1.00X2.10M) CON VISOR DE VIDRIO E=6MM, CON LAMINA DE SEGURIDAD Y CERRAJERIA | 30d | 2023-11-09 | 2023-12-14 | 331FS-20d | 0d | 89,830.76 | 03.06.01 |
| 334 | 1.4.6.2 | SUMINISTRO Y COLOCACION DE PUERTAS DE MADERA CEDRO MACHIEMMBRADA (1.80X2.10M) CON VISOR DE VIDRIO E=6MM, CON LAMINA DE SEGURIDAD Y CERRAJERIA | 30d | 2023-11-09 | 2023-12-14 | 333SS | 0d | 64,406.77 | 03.06.02 |
| 335 | 1.4.6.3 | SUMINISTRO Y COLOCACION DE PUERTAS DE MADERA CEDRO MACHIEMMBRADA (0.90X2.10M) CON CERRAJERIA | 30d | 2023-11-09 | 2023-12-14 | 334SS | 0d | 45,762.6 | 03.06.03 |
| 336 | 1.4.6.4 | SUMINISTRO Y COLOCACION DE PUERTAS DE MADERA CEDRO MACHIEMMBRADA (0.80X2.10M) CON CERRAJERIA | 30d | 2023-11-09 | 2023-12-14 | 335SS | 0d | 5,423.72 | 03.06.04 |
| 337 | 1.4.6.5 | SUMINISTRO Y COLOCACION DE PUERTAS DE MADERA CEDRO MACHIEMMBRADA (1.00X2.10) CON FRESQUILLO H=1.10M Y CERRAJERIA | 30d | 2023-11-09 | 2023-12-14 | 336SS | 0d | 8,474.6 | 03.06.05 |
| 338 | 1.4.6.6 | SUMINISTRO Y COLOCACION DE PUERTAS DE MADERA CEDRO MACHIEMMBRADA (1.20X2.10) CON FRESQUILLO H=1.10M Y CERRAJERIA | 30d | 2023-11-09 | 2023-12-14 | 337SS | 0d | 13,050.87 | 03.06.06 |
| 339 | 1.4.6.7 | SUMINISTRO Y COLOCACION DE PUERTAS DE MADERA CEDRO MACHIEMMBRADA (1.50X2.30) CON CERRAJERIA | 30d | 2023-11-09 | 2023-12-14 | 338SS | 0d | 2,966.1 | 03.06.07 |
| 340 | 1.4.6.8 | SUMINISTRO Y COLOCACION DE PUERTAS DE MADERA CEDRO MACHIEMMBRADA (1.50X2.10) BATIENTE | 30d | 2023-11-09 | 2023-12-14 | 339SS | 0d | 2,542.37 | 03.06.08 |
| 341 | 1.4.6.9 | SUMINISTRO Y COLOCACION DE PUERTAS DE MADERA MACHIEMMBRADA (1.00X2.10) CON FRESQUILLO H=1.10M Y CERRAJERIA | 30d | 2023-11-09 | 2023-12-14 | 340SS | 0d | 16,949.2 | 03.06.09 |
| 342 | 1.4.6.10 | SUMINISTRO Y COLOCACION DE PUERTAS DE MADERA MACHIEMMBRADA (0.90X2.10) CON FRESQUILLO H=1.10M Y CERRAJERIA | 30d | 2023-11-09 | 2023-12-14 | 341SS | 0d | 4,576.26 | 03.06.10 |
| 343 | 1.4.6.11 | SUMINISTRO Y COLOCACION DE PUERTAS DE MADERA MACHIEMMBRADA (0.90X2.65) CON FRESQUILLO H=1.10M Y CERRAJERIA | 30d | 2023-11-09 | 2023-12-14 | 342SS | 0d | 1,864.41 | 03.06.11 |
| 344 | 1.4.6.12 | SUMINISTRO Y COLOCACION DE PUERTAS DE MADERA CONTRAPLACADA (0.70X2.10) CON CERRAJERIA | 30d | 2023-11-09 | 2023-12-14 | 343SS | 0d | 1,101.7 | 03.06.12 |
| 345 | 1.4.6.13 | SUMINISTRO Y COLOCACION DE REPOSTERO DE MELAMINE TIPO 1 H=0.70M, SEGÚN DISEÑO | 30d | 2023-11-09 | 2023-12-14 | 344SS | 0d | 9,655.95 | 03.06.13 |
| 346 | 1.4.6.14 | SUMINISTRO Y COLOCACION DE REPOSTERO DE MELAMINE TIPO 2 H=0.70M, SEGÚN DISEÑO | 30d | 2023-11-09 | 2023-12-14 | 345SS | 0d | 11,091.52 | 03.06.14 |
| 347 | 1.4.6.15 | SUMINISTRO Y COLOCACION DE REPOSTERO DE MELAMINE TIPO 3 H=0.70M, SEGÚN DISEÑO | 30d | 2023-11-09 | 2023-12-14 | 346SS | 0d | 17,491.5 | 03.06.15 |
| 348 | 1.4.6.16 | SUMINISTRO Y COLOCACION DE REPOSTERO DE MELAMINE TIPO 4 H=0.70M, SEGÚN DISEÑO | 30d | 2023-11-09 | 2023-12-14 | 347SS | 0d | 4,993.23 | 03.06.16 |
| 349 | 1.4.6.17 | DIVISIONES DE MELAMINE RESISTENTE A LA HUMEDAD TIPO RH SANITARIO CON PUERTA, SEGUN DISEÑO, INCLUYE ACCESORIOS METALICOS | 30d | 2023-11-09 | 2023-12-14 | 348SS | 0d | 51,545.84 | 03.06.17 |
| 350 | 1.4.6.18 | DIVISIONES DE MELAMINE RESISTENTE A LA HUMEDAD TIPO RH SANITARIO EN URINARIO, INCLUYE ACCESORIOS METALICOS | 30d | 2023-11-09 | 2023-12-14 | 349SS | 0d | 3,849.99 | 03.06.18 |
| 351 | 1.4.6.19 | MUROS CON PLANCHAS DE FIBROCEMENTO e=6mm, EN INTERIORES | 30d | 2023-11-09 | 2023-12-14 | 350SS | 0d | 5,920.37 | 03.06.19 |

| ID | WBS | Task | Duration | Start | Finish | Predecessors | Total slack | Cost | Text1 |
| --- | --- | --- | --- | --- | --- | --- | --- | --- | --- |
| 352 | 1.4.7 | **CARPINTERIA METALICA** | 30d | 2023-11-21 | 2023-12-26 |  | 0d | 1,089,192.83 | 03.07 |
| 353 | 1.4.7.1 | SUMINISTRO Y COLOCACION DE PUERTAS METALICAS 1.70X2.60 (TIPO REJA) | 30d | 2023-11-21 | 2023-12-26 | 351SS+10d | 0d | 21,145.28 | 03.07.01 |
| 354 | 1.4.7.2 | SUMINISTRO Y COLOCACION DE PUERTAS METALICAS 1.80X2.60 (TIPO REJA) | 30d | 2023-11-21 | 2023-12-26 | 353SS | 0d | 2,800 | 03.07.02 |
| 355 | 1.4.7.3 | SUMINISTRO Y COLOCACION DE PUERTAS METALICAS 6.0X2.60 (TIPO REJA) | 30d | 2023-11-21 | 2023-12-26 | 354SS | 0d | 9,328.8 | 03.07.03 |
| 356 | 1.4.7.4 | SUMINISTRO Y COLOCACION DE VENTANA ENMARCADA EN ALUMINIO Y VIDRIO DE 6MM CON LAMINA DE SEGURIDAD, INC ACCESORIOS, SEGÚN DISEÑO | 30d | 2023-11-21 | 2023-12-26 | 355SS | 0d | 588,241.95 | 03.07.04 |
| 357 | 1.4.7.5 | SUMINISTRO Y COLOCACION PROTECTOR METALICO PM-1 (3.64X2.45), SEGÚN DISEÑO | 30d | 2023-11-21 | 2023-12-26 | 356SS | 0d | 13,377 | 03.07.05 |
| 358 | 1.4.7.6 | SUMINISTRO Y COLOCACION PROTECTOR METALICO PM-2 (3.64X2.17), SEGÚN DISEÑO | 30d | 2023-11-21 | 2023-12-26 | 357SS | 0d | 5,924.1 | 03.07.06 |
| 359 | 1.4.7.7 | SUMINISTRO Y COLOCACION PROTECTOR METALICO PM-3 (3.15X2.20), SEGÚN DISEÑO | 30d | 2023-11-21 | 2023-12-26 | 358SS | 0d | 17,325 | 03.07.07 |
| 360 | 1.4.7.8 | SUMINISTRO Y COLOCACION PROTECTOR METALICO PM-4 (3.275X1.10), SEGÚN DISEÑO | 30d | 2023-11-21 | 2023-12-26 | 359SS | 0d | 3,602.52 | 03.07.08 |
| 361 | 1.4.7.9 | SUMINISTRO Y COLOCACION PROTECTOR METALICO PM-5 (1.88X1.10), SEGÚN DISEÑO | 30d | 2023-11-21 | 2023-12-26 | 360SS | 0d | 1,034 | 03.07.09 |
| 362 | 1.4.7.10 | SUMINISTRO Y COLOCACION PROTECTOR METALICO PM-6 (1.23X2.20), SEGÚN DISEÑO | 30d | 2023-11-21 | 2023-12-26 | 361SS | 0d | 676.5 | 03.07.10 |
| 363 | 1.4.7.11 | SUMINISTRO Y COLOCACION PROTECTOR METALICO PM-7 (0.85X0.80), SEGÚN DISEÑO | 30d | 2023-11-21 | 2023-12-26 | 362SS | 0d | 680 | 03.07.11 |
| 364 | 1.4.7.12 | SUMINISTRO Y COLOCACION PROTECTOR METALICO PM-8 (3.15X2.13), SEGÚN DISEÑO | 30d | 2023-11-21 | 2023-12-26 | 363SS | 0d | 6,711.2 | 03.07.12 |
| 365 | 1.4.7.13 | SUMINISTRO Y COLOCACION PROTECTOR METALICO PM-9 (0.85X0.73), SEGÚN DISEÑO | 30d | 2023-11-21 | 2023-12-26 | 364SS | 0d | 620.52 | 03.07.13 |
| 366 | 1.4.7.14 | SUMINISTRO Y COLOCACION PROTECTOR METALICO PM-10 (1.23X2.13), SEGÚN DISEÑO | 30d | 2023-11-21 | 2023-12-26 | 365SS | 0d | 1,309.96 | 03.07.14 |
| 367 | 1.4.7.15 | SUMINISTRO Y COLOCACION PROTECTOR METALICO PM-11 (3.15X1.03), SEGÚN DISEÑO | 30d | 2023-11-21 | 2023-12-26 | 366SS | 0d | 1,622.26 | 03.07.15 |
| 368 | 1.4.7.16 | SUMINISTRO Y COLOCACION PROTECTOR METALICO PM-12 (3.05X2.20), SEGÚN DISEÑO | 30d | 2023-11-21 | 2023-12-26 | 367SS | 0d | 5,032.5 | 03.07.16 |
| 369 | 1.4.7.17 | SUMINISTRO Y COLOCACION PROTECTOR METALICO PM-13 (1.88X1.03), SEGÚN DISEÑO | 30d | 2023-11-21 | 2023-12-26 | 368SS | 0d | 484.1 | 03.07.17 |
| 370 | 1.4.7.18 | SUMINISTRO Y COLOCACION PASAMANOS METALICA DE ACERO INOXIDABLE Ø 2" SEGÚN DISEÑO | 30d | 2023-11-21 | 2023-12-26 | 369SS | 0d | 24,635.71 | 03.07.18 |
| 371 | 1.4.7.19 | BARANDA METALICA DE ACERO INOXIDABLE Ø 2" TIPO 1 SEGÚN DISEÑO | 30d | 2023-11-21 | 2023-12-26 | 370SS | 0d | 41,524 | 03.07.19 |
| 372 | 1.4.7.20 | BARANDA METALICA DE ACERO INOXIDABLE Ø 2" TIPO 2 SEGÚN DISEÑO H=0.35M | 30d | 2023-11-21 | 2023-12-26 | 371SS | 0d | 86,274 | 03.07.20 |
| 373 | 1.4.7.21 | BARANDA METALICA DE ACERO INOXIDABLE Ø 2" TIPO 3 SEGÚN DISEÑO H=0.90M | 30d | 2023-11-21 | 2023-12-26 | 372SS | 0d | 24,543 | 03.07.21 |
| 374 | 1.4.7.22 | SUMINISTRO Y COLOCACION DE ESCALERA METALICA TIPO GATO | 30d | 2023-11-21 | 2023-12-26 | 373SS | 0d | 3,049.36 | 03.07.22 |
| 375 | 1.4.7.23 | SUMINISTRO Y COLOCACION DE TAPA JUNTAS DE ALUMINIO DE 6" PARA PISOS | 30d | 2023-11-21 | 2023-12-26 | 374SS | 0d | 4,444.21 | 03.07.23 |
| 376 | 1.4.7.24 | SUMINISTRO Y COLOCACION DE TAPA JUNTAS DE ALUMINIO DE 6" PARA MUROS Y CIELO RASO | 30d | 2023-11-21 | 2023-12-26 | 375SS | 0d | 26,363.64 | 03.07.24 |
| 377 | 1.4.7.25 | SUMINISTRO Y COLOCACION DE TAPA JUNTAS EN SEPARACION DE COBERTURA TIPO U Y TIPO L | 30d | 2023-11-21 | 2023-12-26 | 376SS | 0d | 16,470.45 | 03.07.25 |
| 378 | 1.4.7.26 | SUMINISTRO Y COLOCACION DE ASTA DE BANDERA | 30d | 2023-11-21 | 2023-12-26 | 377SS | 0d | 4,318.72 | 03.07.26 |
| 379 | 1.4.7.27 | CERCO METALICO CON T°F°N° 1"X2" E=2.00MM H=2.60M | 30d | 2023-11-21 | 2023-12-26 | 378SS | 0d | 1,481.11 | 03.07.27 |
| 380 | 1.4.7.28 | SUMINISTRO Y COLOCACION DE PARASOLES METALICOS. SEGÚN DISEÑO INC. ACCESORIOS DE SUJECION Y PINTADO | 30d | 2023-11-21 | 2023-12-26 | 379SS | 0d | 65,865.4 | 03.07.28 |
| 381 | 1.4.7.29 | ESTRUCTURA METALICA PARA SOMBRA EN BANCAS | 30d | 2023-11-21 | 2023-12-26 | 380SS | 0d | 10,800 | 03.07.29 |
| 382 | 1.4.7.30 | BARANDA DE ACERO INOXIDABLE P/SS. HH. DISCAPACITADOS L=1.00M | 30d | 2023-11-21 | 2023-12-26 | 381SS | 0d | 5,287.04 | 03.07.30 |
| 383 | 1.4.7.31 | SUMINISTRO Y COLOCACION DE REJILLA METALICA CON ANGULO DE 1 1/2" x 1 1/2" x 3/16" Y PLATINA 1" x 1" x 1/8" PARA CUNETAS, SEGUN DISEÑO INC. PINTADO | 30d | 2023-11-21 | 2023-12-26 | 382SS | 0d | 92,098.27 | 03.07.31 |
| 384 | 1.4.7.32 | SUM. Y COLOC. DE COLUMNAS DE T°F° N° 4"x4" INC. PINTADO | 30d | 2023-11-21 | 2023-12-26 | 383SS | 0d | 1,593.06 | 03.07.32 |
| 385 | 1.4.7.33 | TAPA METALICA DE PLANCHA ESTRIADA 3/16" LAF (1.10x1.10m), INC. ACCESORIOS DE CERRAJERIA Y PINTADO | 30d | 2023-11-21 | 2023-12-26 | 384SS | 0d | 529.17 | 03.07.33 |

| ID | WBS | Task | Duration | Start | Finish | Predecessors | Total slack | Free slack | Cost | Text1 |
| --- | --- | --- | --- | --- | --- | --- | --- | --- | --- | --- |
| 386 | 1.4.8 | **CERRAJERIA** | 30d | 2023-11-21 | 2023-12-26 |  | 0d |  | 3,192.16 | 03.08 |
| 387 | 1.4.8.1 | SUMINISTRO Y COLOCACION DE BISAGRA ALUMINIZADA DE 4" | 30d | 2023-11-21 | 2023-12-26 | 385SS | 0d |  | 1,644.36 | 03.08.01 |
| 388 | 1.4.8.2 | SUMINISTRO Y COLOCACION DE CERROJO ALUMINIZADO DE 2" INCL. MANIJA | 30d | 2023-11-21 | 2023-12-26 | 387SS | 0d |  | 1,547.8 | 03.08.02 |
| 389 | 1.4.9 | **OTROS** | 122d | 2023-09-18 | 2024-02-07 |  | 19d |  | 1,085,970.37 | 03.09 |
| 390 | 1.4.9.1 | **JUNTAS DE DILATACION** | 25d | 2023-09-23 | 2023-10-23 |  | 111d |  | 228,550.87 | 03.09.01 |
| 391 | 1.4.9.1.1 | JUNTA DE DILATACION e=1" | 25d | 2023-09-23 | 2023-10-23 | 322SS | 111d | 0d | 4,209.65 | 03.09.01.01 |
| 392 | 1.4.9.1.2 | JUNTA DE DILATACION e=3/4" EN LOSAS DEPORTIVA SECUNDARIA Y PATIOS | 25d | 2023-09-23 | 2023-10-23 | 391SS | 111d | 0d | 5,829.2 | 03.09.01.02 |
| 393 | 1.4.9.1.3 | JUNTA VERTICAL CON SELLO ELASTOMERICO e=1" | 25d | 2023-09-23 | 2023-10-23 | 392SS | 111d | 0d | 25,493.08 | 03.09.01.03 |
| 394 | 1.4.9.1.4 | SARDINEL DE VEREDA 0.20x0.40 F'C=175 KG/CM2 | 25d | 2023-09-23 | 2023-10-23 | 393SS | 111d | 0d | 115,100.72 | 03.09.02 |
| 395 | 1.4.9.1.5 | CONCRETO EN GRADERIAS Y RAMPAS PEATONALES F'C=175KG/CM2 E=10CM, ACABADO FROTACHADO FINO Y BRUÑADO INC. SARDINELES | 25d | 2023-09-23 | 2023-10-23 | 394SS | 111d | 0d | 42,010.63 | 03.09.03 |
| 396 | 1.4.9.1.6 | JUNTA DE DILATACION FLEXIBLE e=3/4 CON POLIURETANO EN LOSA DEPORTIVA PRIMARIA | 25d | 2023-09-23 | 2023-10-23 | 395SS | 111d | 0d | 3,695.2 | 03.09.04 |
| 397 | 1.4.9.1.7 | SARDINEL DE (0.20x0.50 ) F'C=175 KG/CM2 EN LOSAS DEPORTIVA | 25d | 2023-09-23 | 2023-10-23 | 396SS | 111d | 0d | 11,655 | 03.09.05 |
| 398 | 1.4.9.1.8 | SARDINEL DE (0.20x0.60 ) F'C=175 KG/CM2 | 25d | 2023-09-23 | 2023-10-23 | 397SS | 111d | 0d | 558.43 | 03.09.06 |
| 399 | 1.4.9.1.9 | BRUÑAS e=1cm EN MUROS EXTERIORES E INTERIORES | 25d | 2023-09-23 | 2023-10-23 | 398SS | 111d |  | 19,998.96 | 03.09.07 |
| 400 | 1.4.9.2 | **SEÑALES INFORMATIVAS DE SEGURIDAD** | 20d | 2024-01-15 | 2024-02-07 |  | 19d |  | 520,399.98 | 03.09.08 |
| 401 | 1.4.9.2.1 | SUMINISTRO Y COLOCACION DE SEÑALIZACION ADOSADO A PARED 0.20x0.30m | 8d | 2024-01-15 | 2024-01-24 | 314FS-6d | 19d | 0d | 8,684.9 | 03.09.08.01 |
| 402 | 1.4.9.2.2 | SUMINISTRO Y COLOCACION DE SEÑALIZACION ADOSADO A PARED 0.30x0.40m | 8d | 2024-01-15 | 2024-01-24 | 401SS | 19d | 0d | 686.56 | 03.09.08.02 |
| 403 | 1.4.9.2.3 | SUMINISTRO Y COLOCACION DE EXTINTORES | 20d | 2024-01-15 | 2024-02-07 | 402SS | 19d | 0d | 12,827.52 | 03.09.08.03 |
| 404 | 1.4.9.2.4 | SUMINISTRO Y COLOCACION DE GRASS NATURAL | 20d | 2024-01-15 | 2024-02-07 | 403SS | 19d | 0d | 56,385.97 | 03.09.09 |
| 405 | 1.4.9.2.5 | SUMINISTRO Y COLOCACION DE TIERRA DE CULTIVO h=0.20m | 20d | 2024-01-15 | 2024-02-07 | 404SS | 19d | 0d | 27,798.47 | 03.09.10 |
| 406 | 1.4.9.2.6 | SUMINISTRO Y COLOCACION DE GRASS ARTIFICIAL SINTETICO | 20d | 2024-01-15 | 2024-02-07 | 405SS | 19d | 0d | 406,134 | 03.09.11 |
| 407 | 1.4.9.2.7 | SUMINISTRO Y COLOCACION DE GARGOLAS DE C° PREFABRICADA | 20d | 2024-01-15 | 2024-02-07 | 406SS | 19d | 0d | 7,882.56 | 03.09.12 |
| 408 | 1.4.9.3 | **MESAS DE CONCRETO** | 15d | 2023-09-18 | 2023-10-05 |  | 126d |  | 337,019.52 | 03.09.13 |
| 409 | 1.4.9.3.1 | CONCRETO F'C=175 KG/CM2 PARA MESAS | 15d | 2023-09-18 | 2023-10-05 | 316SS | 126d | 0d | 5,574.47 | 03.09.13.01 |
| 410 | 1.4.9.3.2 | ACERO F'Y=4200 KG/CM2 PARA MESAS | 15d | 2023-09-18 | 2023-10-05 | 409SS | 126d | 0d | 4,611.31 | 03.09.13.02 |
| 411 | 1.4.9.3.3 | ENCOFRADO Y DESENCOFRADO DE MESAS DE CONCRETO | 15d | 2023-09-18 | 2023-10-05 | 410SS | 126d | 0d | 6,553.34 | 03.09.13.03 |
| 412 | 1.4.9.3.4 | SUMINISTRO Y COLOCACION DE LETRAS DE ACERO INOXIDABLE SATINADO | 15d | 2023-09-18 | 2023-10-05 | 411SS | 126d | 0d | 3,638.18 | 03.09.14 |
| 413 | 1.4.9.3.5 | SUMINISTRO Y COLOCACION DE INSIGNIA METALICA DE ACERO INOXIDABLE SATINADO | 15d | 2023-09-18 | 2023-10-05 | 412SS | 126d | 0d | 1,206.26 | 03.09.15 |
| 414 | 1.4.9.3.6 | SUMINISTRO Y COLOCACION DE LADRILLO PASTELERO EN COBERTURAS | 15d | 2023-09-18 | 2023-10-05 | 413SS | 126d | 0d | 229,187.64 | 03.09.16 |
| 415 | 1.4.9.3.7 | SUMINISTRO E INSTALACION DE MEMBRANA ASFALTICA EN COBERTURA | 15d | 2023-09-18 | 2023-10-05 | 414SS | 126d | 0d | 4,646.48 | 03.09.17 |
| 416 | 1.4.9.3.8 | CONTRAZOCALO H= 0.10m INC. MEDIA CAÑA PARA EVACUACION PLUVIAL EN CORREDORES Y COBERTURAS | 15d | 2023-09-18 | 2023-10-05 | 415SS | 126d | 0d | 45,983.78 | 03.09.18 |
| 417 | 1.4.9.3.9 | CONCRETO F´C=175KG/CM2 PARA REDIRECCIONAMIENTO DE AGUA PLUVIAL EN CANALETA MEDIA CAÑA | 15d | 2023-09-18 | 2023-10-05 | 416SS | 126d | 0d | 2,518.06 | 03.09.19 |
| 418 | 1.4.9.3.10 | SUMINISTRO Y COLOCACION DE BANCAS DE CONCRETO (1.80x0.45) | 15d | 2023-09-18 | 2023-10-05 | 417SS | 126d | 0d | 24,700 | 03.09.20 |
| 419 | 1.4.9.3.11 | SUMINISTRO Y COLOCACION DE TACHOS PARA BASURA DE 3 DEPOSITOS INC. ACCESORIOS DE ANCLAJE | 15d | 2023-09-18 | 2023-10-05 | 418SS | 126d |  | 8,400 | 03.09.21 |

| ID | WBS | Task | Duration | Start | Finish | Predecessors | Total slack | Free slack | Cost | Text1 |
| --- | --- | --- | --- | --- | --- | --- | --- | --- | --- | --- |
| 420 | 1.4.10 | **TRABAJOS DE REHABILITACION** | 321d | 2023-01-07 | 2024-01-17 |  | 37d |  | 36,223.03 | 03.10 |
| 421 | 1.4.10.1 | REHABILITACION Y COLOCACION DE PUERTAS DE MADERA | 15d | 2023-01-07 | 2023-01-25 | 228SS | 343d | 0d | 1,137.36 | 03.10.01 |
| 422 | 1.4.10.2 | SUMINISTRO Y COLOCACION DE PASAMANO METALICO h=1.00m | 15d | 2023-01-07 | 2023-01-25 | 421SS | 343d | 0d | 1,296.85 | 03.10.02 |
| 423 | 1.4.10.3 | SUMINISTRO Y COLOCACION DE CUMBRERA DE FIBRA VEGETAL | 15d | 2023-01-07 | 2023-01-25 | 422SS | 343d | 0d | 836.17 | 03.10.03 |
| 424 | 1.4.10.4 | SUMINISTRO Y COLOCACION DE COBERTURA LIVIANA DE FIBRA VEGETAL (0.95x2.00m) | 15d | 2023-01-07 | 2023-01-25 | 423SS | 343d | 0d | 12,764.2 | 03.10.04 |
| 425 | 1.4.10.5 | SUMINISTRO Y COLOCACION DE VIGUETAS DE MADERA 2" x 2" | 15d | 2023-01-07 | 2023-01-25 | 424SS | 343d | 0d | 2,934.08 | 03.10.05 |
| 426 | 1.4.10.6 | REHABILITACION DE VENTANA DE MADERA Y VIDRIO | 15d | 2023-01-07 | 2023-01-25 | 425SS | 343d | 0d | 4,875.97 | 03.10.06 |
| 427 | 1.4.10.7 | SUMINISTRO Y COLOCACION DE PUERTA METALICA ENROLLABLE DE 3.94x2.75m | 15d | 2023-01-07 | 2023-01-25 | 426SS | 343d | 0d | 4,000 | 03.10.07 |
| 428 | 1.4.10.8 | SUMINISTRO Y COLOCACION DE PUERTA METALICA ENROLLABLE DE 4.56x2.75m | 15d | 2023-01-07 | 2023-01-25 | 427SS | 343d |  | 4,389 | 03.10.08 |
| 429 | 1.4.10.9 | **DRENAJE PLUVIAL** | 2d | 2024-01-15 | 2024-01-17 |  | 37d |  | 3,989.4 | 03.10.09 |
| 430 | 1.4.10.9.1 | SUMINISTRO E INSTALACION CANALETA DRENAJE PLUVIAL PLANCHA FºGº DE 2mm INC. ACCESORIOS | 2d | 2024-01-15 | 2024-01-17 | 407SS | 37d |  | 3,989.4 | 03.10.09.01 |
| 431 | 1.4.11 | **ACCESORIOS DEPORTIVOS** | 90d | 2023-11-16 | 2024-02-29 |  | 0d |  | 7,627.13 | 03.11 |
| 432 | 1.4.11.1 | ARCOS DE FUTBITO CON TABLERO DE BASQUET (INCLUYE MALLA SEGUN DISEÑO) | 90d | 2023-11-16 | 2024-02-29 | 667SS | 0d |  | 5,084.76 | 03.11.01 |
| 433 | 1.4.11.2 | SUMINISTRO E INSTALACION DE ARCOS C/TUBO 4"X2.5 MM (INCL. MALLA) | 90d | 2023-11-16 | 2024-02-29 | 432SS | 0d |  | 2,542.37 | 03.11.02 |
| 434 | 1.5 | **INSTALACIONES SANITARIAS** | 193d | 2023-06-22 | 2024-02-02 |  | 23d |  | 627,254.16 | 04 |
| 435 | 1.5.1 | **APARATOS SANITARIOS Y ACCESORIOS** | 20d | 2024-01-10 | 2024-02-02 |  | 23d |  | 88,220.46 | 04.01 |
| 436 | 1.5.1.1 | SUMINISTRO DE APARATOS SANITARIO (INODORO) | 20d | 2024-01-10 | 2024-02-02 | 509 | 23d | 0d | 24,069 | 04.01.01 |
| 437 | 1.5.1.2 | SUMINISTRO DE APARATOS SANITARIOS (URINARIOS) | 20d | 2024-01-10 | 2024-02-02 | 436SS | 23d | 0d | 4,472.5 | 04.01.02 |
| 438 | 1.5.1.3 | SUMINISTRO DE APARATOS SANITARIOS (LAVAT. MOD. OVALIN) | 20d | 2024-01-10 | 2024-02-02 | 437SS | 23d | 0d | 13,169.3 | 04.01.03 |
| 439 | 1.5.1.4 | SUMINISTRO DE APARATOS SANITARIOS (LAVATORIO C/PEDESTAL) | 20d | 2024-01-10 | 2024-02-02 | 438SS | 23d | 0d | 688.8 | 04.01.04 |
| 440 | 1.5.1.5 | SUMINISTRO DE APARATOS SANITARIOS (LAVADEROS) | 20d | 2024-01-10 | 2024-02-02 | 439SS | 23d | 0d | 9,269 | 04.01.05 |
| 441 | 1.5.1.6 | SUMINISTRO DE APARATOS SANITARIOS (DUCHAS) | 20d | 2024-01-10 | 2024-02-02 | 440SS | 23d | 0d | 1,006.4 | 04.01.06 |
| 442 | 1.5.1.7 | SUMINISTRO DE ACCESORIOS P/INODOROS | 20d | 2024-01-10 | 2024-02-02 | 441SS | 23d | 0d | 2,269.87 | 04.01.07 |
| 443 | 1.5.1.8 | SUMINISTRO DE ACCESORIOS P/URINARIOS | 20d | 2024-01-10 | 2024-02-02 | 442SS | 23d | 0d | 7,152.75 | 04.01.08 |
| 444 | 1.5.1.9 | SUMINISTRO DE ACCESORIOS P/LAVAT. OVALIN | 20d | 2024-01-10 | 2024-02-02 | 443SS | 23d | 0d | 6,524.61 | 04.01.09 |
| 445 | 1.5.1.10 | SUMINISTRO DE ACCESORIOS P/LAVATORIO C/PEDESTAL | 20d | 2024-01-10 | 2024-02-02 | 444SS | 23d | 0d | 674.58 | 04.01.10 |
| 446 | 1.5.1.11 | SUMINISTRO DE ACCESORIOS P/LAVADEROS | 20d | 2024-01-10 | 2024-02-02 | 445SS | 23d | 0d | 3,485.33 | 04.01.11 |
| 447 | 1.5.1.12 | SUMINISTRO DEACCESORIOS P/DUCHAS | 20d | 2024-01-10 | 2024-02-02 | 446SS | 23d | 0d | 2.72 | 04.01.12 |
| 448 | 1.5.1.13 | INSTALACION DE APARATOS SANITARIOS Y ACCESORIOS | 20d | 2024-01-10 | 2024-02-02 | 447SS | 23d | 0d | 15,435.6 | 04.01.13 |

| ID | WBS | Task | Duration | Start | Finish | Predecessors | Total slack | Free slack | Cost | Text1 |
| --- | --- | --- | --- | --- | --- | --- | --- | --- | --- | --- |
| 449 | 1.5.2 | **SISTEMA DE AGUA FRIA** | 193d | 2023-06-22 | 2024-02-02 |  | 23d |  | 53,431.76 | 04.02 |
| 450 | 1.5.2.1 | **SALIDAS DE AGUA FRIA** | 16d | 2023-06-22 | 2023-07-11 |  | 23d |  | 9,938.52 | 04.02.01 |
| 451 | 1.5.2.1.1 | SALIDA DE AGUA FRIA C-10 Ø 1/2" BRONCE | 16d | 2023-06-22 | 2023-07-11 | 201SS+12d | 23d | 0d | 9,938.52 | 04.02.01.01 |
| 452 | 1.5.2.2 | **REDES DE DISTRIBUCION** | 6d | 2023-07-06 | 2023-07-13 |  | 23d |  | 4,089.38 | 04.02.02 |
| 453 | 1.5.2.2.1 | TUBERIA PVC CLASE 10 SP P/AGUA FRIA D=3/4" | 6d | 2023-07-06 | 2023-07-13 | 451FS-4d | 23d | 0d | 4,089.38 | 04.02.02.01 |
| 454 | 1.5.2.3 | **REDES DE ALIMENTACION** | 20d | 2023-07-11 | 2023-08-03 |  | 23d |  | 9,359.84 | 04.02.03 |
| 455 | 1.5.2.3.1 | TUBERIA PVC ROSCADO C-10 D=2" | 20d | 2023-07-11 | 2023-08-03 | 453FS-2d | 23d | 0d | 3,110.49 | 04.02.03.01 |
| 456 | 1.5.2.3.2 | TUBERIA PVC ROSCADO C-10 D=1 1/2" | 20d | 2023-07-11 | 2023-08-03 | 455SS | 23d | 0d | 3,057.97 | 04.02.03.02 |
| 457 | 1.5.2.3.3 | TUBERIA PVC ROSCADO C-10 D=1" | 20d | 2023-07-11 | 2023-08-03 | 456SS | 23d | 0d | 3,191.38 | 04.02.03.03 |
| 458 | 1.5.2.4 | **ACCESORIOS DE REDES DE AGUA** | 167d | 2023-07-22 | 2024-02-02 |  | 23d |  | 26,134.56 | 04.02.04 |
| 459 | 1.5.2.4.1 | **ACCESORIOS EN REDES DE DISTRIBUCION** | 167d | 2023-07-22 | 2024-02-02 |  | 23d |  | 23,593.15 | 04.02.04.01 |
| 460 | 1.5.2.4.1.1 | SUMINISTRO E INSTALACION DE CODO DE 90° PVC AGUA C-10 3/4" | 16d | 2023-07-22 | 2023-08-10 | 457FS-10d | 23d | 0d | 5,181.54 | 04.02.04.01.01 |
| 461 | 1.5.2.4.1.2 | SUMINISTRO E INSTALACION DE TEE PVC AGUA C-10 3/4" | 16d | 2023-07-22 | 2023-08-10 | 460SS | 23d | 0d | 1,665.2 | 04.02.04.01.02 |
| 462 | 1.5.2.4.1.3 | SUMINISTRO E INSTALACION DE CODO DE BRONCE 1/2" | 16d | 2023-07-22 | 2023-08-10 | 461SS | 23d | 0d | 2,117.62 | 04.02.04.01.03 |
| 463 | 1.5.2.4.1.4 | SUMINISTRO E INSTALACION DE ADAPTADOR PVC AGUA C-10 3/4" | 16d | 2023-07-22 | 2023-08-10 | 462SS | 23d | 0d | 1,819.3 | 04.02.04.01.04 |
| 464 | 1.5.2.4.1.5 | SUMINISTRO E INSTALACION DE NIPLE PVC AGUA C-10 3/4" | 16d | 2023-07-22 | 2023-08-10 | 463SS | 23d | 0d | 1,701.4 | 04.02.04.01.05 |
| 465 | 1.5.2.4.1.6 | SUMINISTRO E INSTALACION DE REDUCCION PVC AGUA C-10 1" A 3/4" | 16d | 2023-07-22 | 2023-08-10 | 464SS | 23d | 0d | 467.18 | 04.02.04.01.06 |
| 466 | 1.5.2.4.1.7 | SUMINISTRO E INSTALACION DE REDUCCION PVC AGUA C-10 3/4 A 1/2" | 16d | 2023-07-22 | 2023-08-10 | 465SS | 174d |  | 1,893.88 | 04.02.04.01.07 |
| 467 | 1.5.2.4.1.8 | SUMINISTRO E INSTALACION DE TUBO DE ABASTO PARA INODORO | 20d | 2024-01-10 | 2024-02-02 | 448SS | 23d | 0d | 2,107.28 | 04.02.04.01.08 |
| 468 | 1.5.2.4.1.9 | SUMINISTRO E INSTALACION DE TUBO DE ABASTO PARA LAVATORIO | 20d | 2024-01-10 | 2024-02-02 | 467SS | 23d |  | 1,792.65 | 04.02.04.01.09 |
| 469 | 1.5.2.4.1.10 | SUMINISTRO E INSTALACION DE TRAMPA PLASTICA C/REGISTRO | 16d | 2023-07-22 | 2023-08-10 | 465SS | 23d | 0d | 3,383.52 | 04.02.04.01.10 |
| 470 | 1.5.2.4.1.11 | SUMINISTRO E INSTALACION DE UNION UNIVERSAL PVC 3/4" | 16d | 2023-07-22 | 2023-08-10 | 469SS | 23d | 0d | 1,463.58 | 04.02.04.01.11 |
| 471 | 1.5.2.4.2 | **ACCESORIOS EN REDES DE ALIMENTACION** | 4d | 2023-08-10 | 2023-08-15 |  | 23d |  | 2,541.41 | 04.02.04.02 |
| 472 | 1.5.2.4.2.1 | SUMINISTRO Y COLOCACION DE CODO 90° PVC SAP Ø 1" | 4d | 2023-08-10 | 2023-08-15 | 470 | 23d | 0d | 595.66 | 04.02.04.02.01 |
| 473 | 1.5.2.4.2.2 | SUMINISTRO Y COLOCACION DE CODO 90° PVC SAP Ø 1 1/2" | 4d | 2023-08-10 | 2023-08-15 | 472SS | 23d | 0d | 245.52 | 04.02.04.02.02 |
| 474 | 1.5.2.4.2.3 | SUMINISTRO Y COLOCACION DE CODO 90° PVC SAP Ø 2" | 4d | 2023-08-10 | 2023-08-15 | 473SS | 23d | 0d | 220.36 | 04.02.04.02.03 |
| 475 | 1.5.2.4.2.4 | SUMINISTRO E INSTALACION DE TEE PVC SAP DE Ø 1" | 4d | 2023-08-10 | 2023-08-15 | 474SS | 23d | 0d | 485.5 | 04.02.04.02.04 |
| 476 | 1.5.2.4.2.5 | SUMINISTRO E INSTALACION DE TEE PVC SAP DE Ø 1 1/2" | 4d | 2023-08-10 | 2023-08-15 | 475SS | 23d | 0d | 176.28 | 04.02.04.02.05 |
| 477 | 1.5.2.4.2.6 | SUMINISTRO E INSTALACION DE TEE PVC SAP DE Ø 2" | 4d | 2023-08-10 | 2023-08-15 | 476SS | 23d | 0d | 323.95 | 04.02.04.02.06 |
| 478 | 1.5.2.4.2.7 | SUMINISTRO E INSTALACION DE REDUCCION PVC AGUA C-10 2" A 1 1/2" | 4d | 2023-08-10 | 2023-08-15 | 477SS | 23d | 0d | 158.2 | 04.02.04.02.07 |
| 479 | 1.5.2.4.2.8 | SUMINISTRO E INSTALACION DE REDUCCION PVC AGUA C-10 2 A 1"" | 4d | 2023-08-10 | 2023-08-15 | 478SS | 23d | 0d | 132 | 04.02.04.02.08 |
| 480 | 1.5.2.4.2.9 | SUMINISTRO E INSTALACION DE REDUCCION PVC AGUA C-10 1 1/2" A 1" | 4d | 2023-08-10 | 2023-08-15 | 479SS | 23d | 0d | 203.94 | 04.02.04.02.09 |

| ID | WBS | Task | Duration | Start | Finish | Predecessors | Total slack | Free slack | Cost | Text1 |
| --- | --- | --- | --- | --- | --- | --- | --- | --- | --- | --- |
| 481 | 1.5.2.5 | **VALVULAS** | 6d | 2023-08-15 | 2023-08-22 |  | 23d |  | 3,909.46 | 04.02.05 |
| 482 | 1.5.2.5.1 | VALVULA COMPUERTA PESADA DE BRONCE DE 3/4" | 6d | 2023-08-15 | 2023-08-22 | 480 | 23d | 0d | 3,909.46 | 04.02.05.01 |
| 483 | 1.5.3 | **SISTEMA CONTRA INCENDIO** | 20d | 2023-08-22 | 2023-09-14 |  | 23d |  | 154,704.54 | 04.03 |
| 484 | 1.5.3.1 | TUBERIA DE ACERO AL CARBONO SCH-40 Ø 2 1/2" (ACI) | 20d | 2023-08-22 | 2023-09-14 | 482 | 23d | 0d | 116,922.9 | 04.03.01 |
| 485 | 1.5.3.2 | **ACCESORIOS DE LA RED DE ALIMENTACION** | 20d | 2023-08-22 | 2023-09-14 |  | 23d |  | 976.1 | 04.03.02 |
| 486 | 1.5.3.2.1 | SUMINISTRO E INSTALACION DE CODO DE 90º SCH-40 2 1/2" (ACI) | 20d | 2023-08-22 | 2023-09-14 | 484SS | 23d | 0d | 462.98 | 04.03.02.01 |
| 487 | 1.5.3.2.2 | SUMINISTRO E INSTALACION DE TEE SCH-40 2 1/2" (ACI) | 20d | 2023-08-22 | 2023-09-14 | 486SS | 23d | 0d | 513.12 | 04.03.02.02 |
| 488 | 1.5.3.3 | SUMINISTRO E INSTALACION DE GABINETE CONTRA INCENDIO INC. ACCESORIOS | 20d | 2023-08-22 | 2023-09-14 | 487SS | 23d | 0d | 34,895.42 | 04.03.03 |
| 489 | 1.5.3.4 | SUMINISTRO E INSTALACION DE VALVULA SIAMESA Y VALVULA CHECK | 20d | 2023-08-22 | 2023-09-14 | 488SS | 23d | 0d | 1,910.12 | 04.03.04 |
| 490 | 1.5.4 | **SISTEMA DE DRENAJE PLUVIAL** | 79d | 2023-10-10 | 2024-01-10 |  | 23d |  | 279,401.67 | 04.04 |
| 491 | 1.5.4.1 | **CUNETAS** | 69d | 2023-10-10 | 2023-12-29 |  | 23d |  | 141,904.83 | 04.04.01 |
| 492 | 1.5.4.1.1 | TRAZO, NIVELACION Y REPLANTEO | 2d | 2023-10-10 | 2023-10-12 | 539SS | 23d | 0d | 1,882.65 | 04.04.01.01 |
| 493 | 1.5.4.1.2 | EXCAVACION MANUAL PARA CUNETAS | 20d | 2023-10-12 | 2023-11-04 | 492 | 23d | 0d | 8,911.83 | 04.04.01.02 |
| 494 | 1.5.4.1.3 | MEJORAMIENTO CON MATERIAL DE PRESTAMO (HORMIGON) e=0.15m | 4d | 2023-11-04 | 2023-11-09 | 493 | 23d | 0d | 7,079.71 | 04.04.01.03 |
| 495 | 1.5.4.1.4 | ENCOFRADO Y DESENCOFRADO DE CUENTA | 14d | 2023-11-07 | 2023-11-23 | 494FS-2d | 23d | 0d | 21,528.48 | 04.04.01.04 |
| 496 | 1.5.4.1.5 | CONCRETO F'C= 175 KG/CM2 - PARA CUNETAS | 6d | 2023-11-18 | 2023-11-25 | 495FS-4d | 23d | 0d | 45,637.86 | 04.04.01.05 |
| 497 | 1.5.4.1.6 | CURADO DE ESTRUCTURAS | 12d | 2023-11-18 | 2023-12-02 | 496SS | 23d | 0d | 3,950.07 | 04.04.01.06 |
| 498 | 1.5.4.1.7 | TUBERIA PVC CLASE 10 SP P/AGUA FRIA D=3" | 30d | 2023-11-24 | 2023-12-29 | 497SS+5d | 23d | 0d | 50,391.71 | 04.04.02 |
| 499 | 1.5.4.1.8 | SUMINISTRO E INSTALACION DE CODO DE 90º PVC AGUA C-10 3" | 30d | 2023-11-24 | 2023-12-29 | 498SS | 23d | 0d | 2,522.52 | 04.04.03 |
| 500 | 1.5.4.2 | **DREN PLUVIAL** | 27d | 2023-12-06 | 2024-01-06 |  | 23d |  | 133,418.89 | 04.04.04 |
| 501 | 1.5.4.2.1 | TRAZO, NIVELACION Y REPLANTEO | 2d | 2023-12-06 | 2023-12-08 | 499SS+10d | 23d | 0d | 1,480.32 | 04.04.04.01 |
| 502 | 1.5.4.2.2 | EXCAVACION CON MAQUINARIA PARA DREN PLUVIAL | 4d | 2023-12-08 | 2023-12-13 | 501 | 23d | 0d | 4,712.03 | 04.04.04.02 |
| 503 | 1.5.4.2.3 | ENCOFRADO Y DESENCOFRADO DE CANAL DE DREN PLUVIAL | 8d | 2023-12-11 | 2023-12-20 | 502SS+2d | 23d | 0d | 4,343.21 | 04.04.04.03 |
| 504 | 1.5.4.2.4 | COLOCACION, NIVELACION Y COMPACTACION CON MATERIAL DE PRESTAMO (HORMIGON) e=0.20m | 3d | 2023-12-18 | 2023-12-21 | 503FS-2d | 23d | 0d | 40,417.65 | 04.04.04.04 |
| 505 | 1.5.4.2.5 | COLOCACION, NIVELACION Y COMPACTACION CON MATERIAL DE PRESTAMO (OVER DE 2" A 3") | 5d | 2023-12-20 | 2023-12-26 | 504SS+2d | 23d | 0d | 14,356.57 | 04.04.04.05 |
| 506 | 1.5.4.2.6 | CONCRETO F'C= 175 KG/CM2 - PARA CANAL DE DREN PLUVIAL | 3d | 2023-12-26 | 2023-12-29 | 505 | 23d | 0d | 29,700.89 | 04.04.04.06 |
| 507 | 1.5.4.2.7 | CURADO DE ESTRUCTURAS | 6d | 2023-12-26 | 2024-01-02 | 506SS | 23d | 0d | 1,421.59 | 04.04.04.07 |
| 508 | 1.5.4.2.8 | SUMINISTRO E INSTALACION DE GEOMEMBRANA DE PVC E=0.5 MM | 4d | 2024-01-02 | 2024-01-06 | 507 | 23d | 0d | 36,986.63 | 04.04.04.08 |
| 509 | 1.5.4.3 | TUBERIA PVC P/ALCANTARILLADO D=8" | 3d | 2024-01-06 | 2024-01-10 | 508 | 23d | 0d | 4,077.95 | 04.04.05 |

| ID | WBS | Task | Duration | Start | Finish | Predecessors | Total slack | Free slack | Cost | Text1 |
| --- | --- | --- | --- | --- | --- | --- | --- | --- | --- | --- |
| 510 | 1.5.5 | **DESAGUE Y VENTILACION** | 42d | 2023-08-24 | 2023-10-12 |  | 23d |  | 51,495.73 | 04.05 |
| 511 | 1.5.5.1 | SALIDAS DE DESAGUE DE PVC 4" | 6d | 2023-08-24 | 2023-08-31 | 489SS+2d | 23d | 0d | 3,610.35 | 04.05.01 |
| 512 | 1.5.5.2 | SALIDAS DE DESAGUE DE PVC 2" | 14d | 2023-08-26 | 2023-09-12 | 511SS+2d | 23d | 0d | 6,152.83 | 04.05.02 |
| 513 | 1.5.5.3 | **REDES DE DERIVACION** | 6d | 2023-09-12 | 2023-09-19 |  | 23d |  | 5,718.18 | 04.05.03 |
| 514 | 1.5.5.3.1 | TUBO DE DESAGUE DE PVC Ø 4" | 3d | 2023-09-12 | 2023-09-15 | 512 | 23d | 0d | 3,670 | 04.05.03.01 |
| 515 | 1.5.5.3.2 | TUBO DE DESAGUE DE PVC Ø 2" | 3d | 2023-09-15 | 2023-09-19 | 514 | 23d | 0d | 2,048.18 | 04.05.03.02 |
| 516 | 1.5.5.4 | **REDES COLECTORAS** | 20d | 2023-09-13 | 2023-10-06 |  | 28d |  | 13,596.58 | 04.05.04 |
| 517 | 1.5.5.4.1 | TUBO DE DESAGUE DE PVC SAP D=6" | 20d | 2023-09-13 | 2023-10-06 | 515FS-5d | 120d | 0d | 5,737.58 | 04.05.04.01 |
| 518 | 1.5.5.4.2 | TUBO DE DESAGUE DE PVC Ø 4" | 6d | 2023-09-19 | 2023-09-26 | 515 | 23d | 0d | 7,076.46 | 04.05.04.02 |
| 519 | 1.5.5.4.3 | TUBO DE DESAGUE DE PVC Ø 2" | 6d | 2023-09-19 | 2023-09-26 | 518SS | 23d | 0d | 782.54 | 04.05.04.03 |
| 520 | 1.5.5.5 | **ACCESORIOS DE REDES DE DESAGUE** | 10d | 2023-09-23 | 2023-10-05 |  | 23d |  | 10,297.62 | 04.05.05 |
| 521 | 1.5.5.5.1 | SUMINISTRO E INSTALACION DE CODO 90° PVC Ø 4" | 10d | 2023-09-23 | 2023-10-05 | 519FS-2d | 23d | 0d | 1,417.32 | 04.05.05.01 |
| 522 | 1.5.5.5.2 | SUMINISTRO E INSTALACION DE CODO 90° PVC Ø 2" | 10d | 2023-09-23 | 2023-10-05 | 521SS | 23d | 0d | 2,284.3 | 04.05.05.02 |
| 523 | 1.5.5.5.3 | SUMINISTRO E INSTALACION DE TEE PVC 4" | 10d | 2023-09-23 | 2023-10-05 | 522SS | 23d | 0d | 406.12 | 04.05.05.03 |
| 524 | 1.5.5.5.4 | SUMINISTRO E INSTALACION DE TEE PVC 2" | 10d | 2023-09-23 | 2023-10-05 | 523SS | 23d | 0d | 123.1 | 04.05.05.04 |
| 525 | 1.5.5.5.5 | SUMINISTRO E INSTALACION DE REGISTRO ROSCADO DE BRONCE DE Ø 4" | 10d | 2023-09-23 | 2023-10-05 | 524SS | 23d | 0d | 798.66 | 04.05.05.05 |
| 526 | 1.5.5.5.6 | SUMINISTRO E INSTALACION DE REGISTRO ROSCADO DE BRONCE DE Ø 2" | 10d | 2023-09-23 | 2023-10-05 | 525SS | 23d | 0d | 146.7 | 04.05.05.06 |
| 527 | 1.5.5.5.7 | SUMINISTRO Y COLOCACION DE SUMIDERO CON TRAMPA P | 10d | 2023-09-23 | 2023-10-05 | 526SS | 23d | 0d | 612.72 | 04.05.05.07 |
| 528 | 1.5.5.5.8 | SUMINISTRO E INSTALACIÓN DE YEE SIMPLE 4" | 10d | 2023-09-23 | 2023-10-05 | 527SS | 23d | 0d | 1,811.18 | 04.05.05.08 |
| 529 | 1.5.5.5.9 | SUMINISTRO E INSTALACIÓN DE YEE SIMPLE 2" | 10d | 2023-09-23 | 2023-10-05 | 528SS | 23d | 0d | 498.96 | 04.05.05.09 |
| 530 | 1.5.5.5.10 | SUMINISTRO E INSTALACIÓN DE YEE DOBLE 4" | 10d | 2023-09-23 | 2023-10-05 | 529SS | 23d | 0d | 40.6 | 04.05.05.10 |
| 531 | 1.5.5.5.11 | SUMINISTRO E INSTALACIÓN DE YEE DE 4" A 2" | 10d | 2023-09-23 | 2023-10-05 | 530SS | 23d | 0d | 1,642.2 | 04.05.05.11 |
| 532 | 1.5.5.5.12 | SUMINISTRO E INSTALACIÓN DE SOMBRERO DE VENTILACION 4" | 10d | 2023-09-23 | 2023-10-05 | 531SS | 23d | 0d | 146.04 | 04.05.05.12 |
| 533 | 1.5.5.5.13 | SUMINISTRO E INSTALACIÓN DE SOMBRERO DE VENTILACION 2" | 10d | 2023-09-23 | 2023-10-05 | 532SS | 23d | 0d | 369.72 | 04.05.05.13 |

| ID | WBS | Task | Duration | Start | Finish | Predecessors | Total slack | Free slack | Cost | Text1 |
| --- | --- | --- | --- | --- | --- | --- | --- | --- | --- | --- |
| 534 | 1.5.5.6 | **CAMARAS DE INSPECCION** | 20d | 2023-09-19 | 2023-10-12 |  | 35d |  | 11,596.59 | 04.05.06 |
| 535 | 1.5.5.6.1 | SUMINISTRO E INSTALACION CAJA REGISTRO | 6d | 2023-10-03 | 2023-10-10 | 533FS-2d | 23d | 0d | 4,140.23 | 04.05.06.01 |
| 536 | 1.5.5.6.2 | SUMINISTRO E INSTALACION DE BUZONETA | 20d | 2023-09-19 | 2023-10-12 | 517SS+5d | 120d | 0d | 1,202.8 | 04.05.06.02 |
| 537 | 1.5.5.6.3 | SUMINISTRO E INSTALACION DE BUZON | 20d | 2023-09-19 | 2023-10-12 | 536SS | 120d |  | 6,253.56 | 04.05.06.03 |
| 538 | 1.5.5.7 | **VARIOS** | 2d | 2023-10-10 | 2023-10-12 |  | 23d |  | 523.58 | 04.05.07 |
| 539 | 1.5.5.7.1 | CONEXION DOMICILIARIA DE DESAGUE | 2d | 2023-10-10 | 2023-10-12 | 535 | 23d | 0d | 523.58 | 04.05.07.01 |
| 540 | 1.6 | **INSTALACIONES ELECTRICAS** | 225d | 2022-12-21 | 2023-09-09 |  | 148d |  | 638,668.84 | 05 |
| 541 | 1.6.1 | **TABLEROS ELECTRICOS** | 90d | 2023-04-11 | 2023-07-25 |  | 188d |  | 69,544.67 | 05.01 |
| 542 | 1.6.1.1 | SUMINISTRO Y COLOCACION DE TABLERO GENERAL (TG) | 90d | 2023-04-11 | 2023-07-25 | 624SS+10d | 188d | 0d | 2,397.14 | 05.01.01 |
| 543 | 1.6.1.2 | SUMINISTRO Y COLOCACION DE SUB_TABLERO STG-1A | 90d | 2023-04-11 | 2023-07-25 | 542SS | 188d | 0d | 3,130.64 | 05.01.02 |
| 544 | 1.6.1.3 | SUMINISTRO Y COLOCACION DE SUB_TABLERO STG-1B | 90d | 2023-04-11 | 2023-07-25 | 543SS | 188d | 0d | 2,753.67 | 05.01.03 |
| 545 | 1.6.1.4 | SUMINISTRO Y COLOCACION DE TABLERO DE DISTRIBUCION - TD-01 | 90d | 2023-04-11 | 2023-07-25 | 544SS | 188d | 0d | 794.84 | 05.01.04 |
| 546 | 1.6.1.5 | SUMINISTRO Y COLOCACION DE TABLERO DE DISTRIBUCION - TD-1.01 | 90d | 2023-04-11 | 2023-07-25 | 545SS | 188d | 0d | 965.84 | 05.01.05 |
| 547 | 1.6.1.6 | SUMINISTRO Y COLOCACION DE TABLERO DE DISTRIBUCION - TD-1.02 | 90d | 2023-04-11 | 2023-07-25 | 546SS | 188d | 0d | 965.84 | 05.01.06 |
| 548 | 1.6.1.7 | SUMINISTRO Y COLOCACION DE TABLERO DE DISTRIBUCION - TD-1.03 | 90d | 2023-04-11 | 2023-07-25 | 547SS | 188d | 0d | 901.84 | 05.01.07 |
| 549 | 1.6.1.8 | SUMINISTRO Y COLOCACION DE TABLERO DE DISTRIBUCION - TD-1.03.01 | 90d | 2023-04-11 | 2023-07-25 | 548SS | 188d | 0d | 1,949.84 | 05.01.08 |
| 550 | 1.6.1.9 | SUMINISTRO Y COLOCACION DE TABLERO DE DISTRIBUCION - TD-1.03.02 | 90d | 2023-04-11 | 2023-07-25 | 549SS | 188d | 0d | 750.02 | 05.01.09 |
| 551 | 1.6.1.10 | SUMINISTRO Y COLOCACION DE TABLERO DE DISTRIBUCION - TD-1.03.03 | 90d | 2023-04-11 | 2023-07-25 | 550SS | 188d | 0d | 567.02 | 05.01.10 |
| 552 | 1.6.1.11 | SUMINISTRO Y COLOCACION DE TABLERO DE DISTRIBUCION - TD-1.04 | 90d | 2023-04-11 | 2023-07-25 | 551SS | 188d | 0d | 900.34 | 05.01.11 |
| 553 | 1.6.1.12 | SUMINISTRO Y COLOCACION DE TABLERO DE DISTRIBUCION - TD-1.05 | 90d | 2023-04-11 | 2023-07-25 | 552SS | 188d | 0d | 1,109.84 | 05.01.12 |
| 554 | 1.6.1.13 | SUMINISTRO Y COLOCACION DE TABLERO DE DISTRIBUCION - TD-1.06 | 90d | 2023-04-11 | 2023-07-25 | 553SS | 188d | 0d | 965.84 | 05.01.13 |
| 555 | 1.6.1.14 | SUMINISTRO Y COLOCACION DE TABLERO DE DISTRIBUCION - TD-1.07 | 90d | 2023-04-11 | 2023-07-25 | 554SS | 188d | 0d | 803.34 | 05.01.14 |
| 556 | 1.6.1.15 | SUMINISTRO Y COLOCACION DE TABLERO DE DISTRIBUCION - TD-1.08 | 90d | 2023-04-11 | 2023-07-25 | 555SS | 188d | 0d | 965.84 | 05.01.15 |
| 557 | 1.6.1.16 | SUMINISTRO Y COLOCACION DE TABLERO DE DISTRIBUCION - TD-1.09 | 90d | 2023-04-11 | 2023-07-25 | 556SS | 188d | 0d | 902.84 | 05.01.16 |
| 558 | 1.6.1.17 | SUMINISTRO Y COLOCACION DE TABLERO DE DISTRIBUCION - TD-1.10 | 90d | 2023-04-11 | 2023-07-25 | 557SS | 188d | 0d | 905.84 | 05.01.17 |
| 559 | 1.6.1.18 | SUMINISTRO Y COLOCACION DE TABLERO DE DISTRIBUCION - TD-1.11 | 90d | 2023-04-11 | 2023-07-25 | 558SS | 188d | 0d | 1,128.57 | 05.01.18 |
| 560 | 1.6.1.19 | SUMINISTRO Y COLOCACION DE TABLERO DE DISTRIBUCION - TD-1.12 | 90d | 2023-04-11 | 2023-07-25 | 559SS | 188d | 0d | 905.84 | 05.01.19 |
| 561 | 1.6.1.20 | SUMINISTRO Y COLOCACION DE TABLERO DE DISTRIBUCION - TD-1.13 | 90d | 2023-04-11 | 2023-07-25 | 560SS | 188d | 0d | 723.52 | 05.01.20 |
| 562 | 1.6.1.21 | SUMINISTRO Y COLOCACION DE TABLERO DE DISTRIBUCION - TD-1.14 | 90d | 2023-04-11 | 2023-07-25 | 561SS | 188d | 0d | 865.34 | 05.01.21 |
| 563 | 1.6.1.22 | SUMINISTRO Y COLOCACION DE SUB TABLERO ST-2.1 | 90d | 2023-04-11 | 2023-07-25 | 562SS | 188d | 0d | 1,533.84 | 05.01.22 |
| 564 | 1.6.1.23 | SUMINISTRO Y COLOCACION DE SUB TABLERO ST-2.2 | 90d | 2023-04-11 | 2023-07-25 | 563SS | 188d | 0d | 1,533.84 | 05.01.23 |
| 565 | 1.6.1.24 | SUMINISTRO Y COLOCACION DE TABLERO DE DISTRIBUCION - TD-2.01 | 90d | 2023-04-11 | 2023-07-25 | 564SS | 188d | 0d | 931.84 | 05.01.24 |
| 566 | 1.6.1.25 | SUMINISTRO Y COLOCACION DE TABLERO DE DISTRIBUCION - TD-2.02 | 90d | 2023-04-11 | 2023-07-25 | 565SS | 188d | 0d | 1,186.84 | 05.01.25 |
| 567 | 1.6.1.26 | SUMINISTRO Y COLOCACION DE TABLERO DE DISTRIBUCION - TD-2.03 | 90d | 2023-04-11 | 2023-07-25 | 566SS | 188d | 0d | 493.52 | 05.01.26 |
| 568 | 1.6.1.27 | SUMINISTRO Y COLOCACION DE TABLERO DE DISTRIBUCION - TD-2.04 | 90d | 2023-04-11 | 2023-07-25 | 567SS | 188d | 0d | 900.34 | 05.01.27 |
| 569 | 1.6.1.28 | SUMINISTRO Y COLOCACION DE TABLERO DE DISTRIBUCION - TD-2.05 | 90d | 2023-04-11 | 2023-07-25 | 568SS | 188d | 0d | 900.34 | 05.01.28 |
| 570 | 1.6.1.29 | SUMINISTRO Y COLOCACION DE TABLERO DE DISTRIBUCION - TD-2.06 | 90d | 2023-04-11 | 2023-07-25 | 569SS | 188d | 0d | 1,016.84 | 05.01.29 |
| 571 | 1.6.1.30 | SUMINISTRO Y COLOCACION DE TABLERO DE DISTRIBUCION - TD-2.07 | 90d | 2023-04-11 | 2023-07-25 | 570SS | 188d | 0d | 1,228.07 | 05.01.30 |
| 572 | 1.6.1.31 | SUMINISTRO Y COLOCACION DE TABLERO DE DISTRIBUCION - TD-2.08 | 90d | 2023-04-11 | 2023-07-25 | 571SS | 188d | 0d | 1,060.84 | 05.01.31 |
| 573 | 1.6.1.32 | SUMINISTRO Y COLOCACION DE TABLERO DE DISTRIBUCION - TD-2.09 | 90d | 2023-04-11 | 2023-07-25 | 572SS | 188d | 0d | 1,083.34 | 05.01.32 |
| 574 | 1.6.1.33 | SUMINISTRO Y COLOCACION DE TABLERO DE DISTRIBUCION - TD-2.10 | 90d | 2023-04-11 | 2023-07-25 | 573SS | 188d | 0d | 1,203.34 | 05.01.33 |
| 575 | 1.6.1.34 | SUMINISTRO Y COLOCACION DE TABLERO DE DISTRIBUCION - TD-2.11 | 90d | 2023-04-11 | 2023-07-25 | 574SS | 188d | 0d | 1,203.34 | 05.01.34 |
| 576 | 1.6.1.35 | SUMINISTRO Y COLOCACION DE TABLERO DE DISTRIBUCION - TD-2.12 | 90d | 2023-04-11 | 2023-07-25 | 575SS | 188d | 0d | 833.84 | 05.01.35 |
| 577 | 1.6.1.36 | SUMINISTRO Y COLOCACION DE SUB_TABLERO ST-3.1 | 90d | 2023-04-11 | 2023-07-25 | 576SS | 188d | 0d | 1,260.34 | 05.01.36 |
| 578 | 1.6.1.37 | SUMINISTRO Y COLOCACION DE SUB_TABLERO ST-3.2 | 90d | 2023-04-11 | 2023-07-25 | 577SS | 188d | 0d | 1,522.34 | 05.01.37 |
| 579 | 1.6.1.38 | SUMINISTRO Y COLOCACION DE TABLERO DE DISTRIBUCION - TD-3.01 | 90d | 2023-04-11 | 2023-07-25 | 578SS | 188d | 0d | 1,156.84 | 05.01.38 |
| 580 | 1.6.1.39 | SUMINISTRO Y COLOCACION DE TABLERO DE DISTRIBUCION - TD-3.02 | 90d | 2023-04-11 | 2023-07-25 | 579SS | 188d | 0d | 525.02 | 05.01.39 |
| 581 | 1.6.1.40 | SUMINISTRO Y COLOCACION DE TABLERO DE DISTRIBUCION - TD-3.03 | 90d | 2023-04-11 | 2023-07-25 | 580SS | 188d | 0d | 853.02 | 05.01.40 |
| 582 | 1.6.1.41 | SUMINISTRO Y COLOCACION DE TABLERO DE DISTRIBUCION - TD-3.04 | 90d | 2023-04-11 | 2023-07-25 | 581SS | 188d | 0d | 931.84 | 05.01.41 |
| 583 | 1.6.1.42 | SUMINISTRO Y COLOCACION DE TABLERO DE DISTRIBUCION - TD-3.05 | 90d | 2023-04-11 | 2023-07-25 | 582SS | 188d | 0d | 896.84 | 05.01.42 |
| 584 | 1.6.1.43 | SUMINISTRO Y COLOCACION DE TABLERO DE DISTRIBUCION - TD-3.06 | 90d | 2023-04-11 | 2023-07-25 | 583SS | 188d | 0d | 1,228.07 | 05.01.43 |
| 585 | 1.6.1.44 | SUMINISTRO Y COLOCACION DE TABLERO DE DISTRIBUCION - TD-3.07 | 90d | 2023-04-11 | 2023-07-25 | 584SS | 188d | 0d | 1,003.07 | 05.01.44 |
| 586 | 1.6.1.45 | SUMINISTRO Y COLOCACION DE TABLERO DE DISTRIBUCION - TD-3.08 | 90d | 2023-04-11 | 2023-07-25 | 585SS | 188d | 0d | 1,083.34 | 05.01.45 |
| 587 | 1.6.1.46 | SUMINISTRO Y COLOCACION DE TABLERO DE DISTRIBUCION - TD-3.09 | 90d | 2023-04-11 | 2023-07-25 | 586SS | 188d | 0d | 1,290.34 | 05.01.46 |
| 588 | 1.6.1.47 | SUMINISTRO Y COLOCACION DE TABLERO DE DISTRIBUCION - TD-3.10 | 90d | 2023-04-11 | 2023-07-25 | 587SS | 188d | 0d | 1,203.34 | 05.01.47 |
| 589 | 1.6.1.48 | SUMINISTRO Y COLOCACION DE TABLERO DE DISTRIBUCION - TD-3.11 | 90d | 2023-04-11 | 2023-07-25 | 588SS | 188d | 0d | 603.84 | 05.01.48 |
| 590 | 1.6.1.49 | SUMINISTRO Y COLOCACION DE SUB_ TABLERO ST-4.2 | 90d | 2023-04-11 | 2023-07-25 | 589SS | 188d | 0d | 865.34 | 05.01.49 |
| 591 | 1.6.1.50 | SUMINISTRO Y COLOCACION DE TABLERO DE DISTRIBUCION - TD-4.01 | 90d | 2023-04-11 | 2023-07-25 | 590SS | 188d | 0d | 1,228.07 | 05.01.50 |
| 592 | 1.6.1.51 | SUMINISTRO Y COLOCACION DE TABLERO DE DISTRIBUCION - TD-4.02 | 90d | 2023-04-11 | 2023-07-25 | 591SS | 188d | 0d | 972.34 | 05.01.51 |
| 593 | 1.6.1.52 | SUMINISTRO Y COLOCACION DE TABLERO DE DISTRIBUCION - TD-4.03 | 90d | 2023-04-11 | 2023-07-25 | 592SS | 188d | 0d | 972.34 | 05.01.52 |
| 594 | 1.6.1.53 | SUMINISTRO Y COLOCACION DE TABLERO DE DISTRIBUCION - TD-4.04 | 90d | 2023-04-11 | 2023-07-25 | 593SS | 188d | 0d | 572.34 | 05.01.53 |
| 595 | 1.6.1.54 | SUMINISTRO Y COLOCACION DE TABLERO DE CONTROL EQUIPO SOLAR TPS | 90d | 2023-04-11 | 2023-07-25 | 594SS | 188d | 0d | 945.34 | 05.01.54 |
| 596 | 1.6.1.55 | SUMINISTRO Y COLOCACION DE TABLERO DE CONTROL ELECTROBOMBA TEB | 90d | 2023-04-11 | 2023-07-25 | 595SS | 188d | 0d | 1,513.2 | 05.01.55 |
| 597 | 1.6.1.56 | SUMINISTRO Y COLOCACION DE BUZON DE CONCRETO | 90d | 2023-04-11 | 2023-07-25 | 596SS | 188d | 0d | 5,443.24 | 05.01.56 |
| 598 | 1.6.1.57 | SUMINISTRO Y COLOCACION DE CAJA BORNERA 03 CIRCUITOS | 90d | 2023-04-11 | 2023-07-25 | 597SS | 188d | 0d | 2,609.04 | 05.01.57 |
| 599 | 1.6.1.58 | SUMINISTRO Y COLOCACION DE CAJA DE PASE 200x200x100 PVC | 90d | 2023-04-11 | 2023-07-25 | 598SS | 188d |  | 401.17 | 05.01.58 |

| ID | WBS | Task | Duration | Start | Finish | Predecessors | Total slack | Free slack | Cost | Text1 |
| --- | --- | --- | --- | --- | --- | --- | --- | --- | --- | --- |
| 600 | 1.6.2 | **CONDUCTORES ALIMENTADORES** | 45d | 2022-12-21 | 2023-02-11 |  | 148d |  | 82,571.85 | 05.02 |
| 601 | 1.6.2.1 | SUMINISTRO E INSTALACION DE CONDUCTOR N2XOH 3-1 x 35 + 25mm2 (MEDIDOR A TG) | 45d | 2022-12-21 | 2023-02-11 | 224SS+60d | 148d | 0d | 1,931.38 | 05.02.01 |
| 602 | 1.6.2.2 | SUMINISTRO E INSTALACION DE CONDUCTOR N2XOH 3-1 x 25 + 25 mm2 (TG - STG) | 45d | 2022-12-21 | 2023-02-11 | 601SS | 148d | 0d | 7,049.96 | 05.02.02 |
| 603 | 1.6.2.3 | SUMINISTRO E INSTALACION DE CONDUCTOR N2XOH 3-1 x 16 +16 mm2 (STG - TD) | 45d | 2022-12-21 | 2023-02-11 | 602SS | 148d | 0d | 12,093.32 | 05.02.03 |
| 604 | 1.6.2.4 | SUMINISTRO E INSTALACION DE CONDUCTOR N2XOH 3-1 x 16 + 1 x 10 (N) | 45d | 2022-12-21 | 2023-02-11 | 603SS | 148d | 0d | 20,800 | 05.02.04 |
| 605 | 1.6.2.5 | SUMINISTRO E INSTALACION DE CONDUCTOR N2XOH 3-1 x 10 + 1 x 10 (N) | 45d | 2022-12-21 | 2023-02-11 | 604SS | 148d | 0d | 12,040 | 05.02.05 |
| 606 | 1.6.2.6 | SUMINISTRO E INSTALACION DE CONDUCTOR N2XOH 2-1 x 10 mm2 | 45d | 2022-12-21 | 2023-02-11 | 605SS | 148d | 0d | 9,198.15 | 05.02.06 |
| 607 | 1.6.2.7 | SUMINISTRO E INSTALACION DE CONDUCTOR N2XOH (3x6+1x6) mm2 | 45d | 2022-12-21 | 2023-02-11 | 606SS | 148d | 0d | 4,658.62 | 05.02.07 |
| 608 | 1.6.2.8 | SUMINISTRO E INSTALACION DE CONDUCTOR N2XOH 2-1 x 16 mm2 | 45d | 2022-12-21 | 2023-02-11 | 607SS | 148d | 0d | 10,080 | 05.02.08 |
| 609 | 1.6.2.9 | SUMINISTRO y TENDIDO CONDUCTOR AUTOPORTANTE CAAI 3-1 x 35 + 1x25mm2 | 45d | 2022-12-21 | 2023-02-11 | 608SS | 148d | 0d | 2,444.98 | 05.02.09 |
| 610 | 1.6.2.10 | SUMINISTRO y TENDIDO CONDUCTOR NLT 2-1 x 06 mm2 | 45d | 2022-12-21 | 2023-02-11 | 609SS | 148d | 0d | 2,275.44 | 05.02.10 |
| 611 | 1.6.3 | **INSTALACION DE INTERIORES** | 180d | 2023-02-11 | 2023-09-09 |  | 148d |  | 219,847.77 | 05.03 |
| 612 | 1.6.3.1 | SALIDA DE CENTRO DE LUZ PARA UN PUNTO | 70d | 2023-02-11 | 2023-05-04 | 610 | 148d | 0d | 3,004.26 | 05.03.01 |
| 613 | 1.6.3.2 | SALIDA DE CENTRO DE LUZ PARA DOS PUNTOS | 70d | 2023-02-11 | 2023-05-04 | 612SS | 148d | 0d | 9,027.65 | 05.03.02 |
| 614 | 1.6.3.3 | SALIDA DE CENTRO DE LUZ PARA CUATRO PUNTOS | 70d | 2023-02-11 | 2023-05-04 | 613SS | 148d | 0d | 20,518.76 | 05.03.03 |
| 615 | 1.6.3.4 | SALIDA DE CENTRO DE LUZ PARA SEIS PUNTOS | 70d | 2023-02-11 | 2023-05-04 | 614SS | 148d | 0d | 7,630.28 | 05.03.04 |
| 616 | 1.6.3.5 | SUM. E INST. DE EQUIPO LUMINARIA TIPO PANEL LED 48W, ADOSADA AL TECHO | 25d | 2023-08-11 | 2023-09-09 | 653 | 148d | 0d | 65,565.85 | 05.03.05 |
| 617 | 1.6.3.6 | SUM. E INST. DE EQUIPO LUMINARIA CIRCULAR LED DE 18W | 25d | 2023-08-11 | 2023-09-09 | 616SS | 148d |  | 30,290.85 | 05.03.06 |
| 618 | 1.6.3.7 | SALIDA DE CENTRO DE LUZ CONMUTACION: ESCALERA: ESCALERA Y PASILLOS | 70d | 2023-02-11 | 2023-05-04 | 615SS | 148d | 0d | 1,090.04 | 05.03.07 |
| 619 | 1.6.3.8 | SALIDA PARA PUNTO DE VENTILADORES DE TECHO | 70d | 2023-02-11 | 2023-05-04 | 618SS | 148d | 0d | 12,211.68 | 05.03.08 |
| 620 | 1.6.3.9 | SUMINISTRO E INSTALACION DE VENTILADORES | 70d | 2023-02-11 | 2023-05-04 | 619SS | 148d | 0d | 23,056.8 | 05.03.09 |
| 621 | 1.6.3.10 | SALIDA DE CENTRO DE TOMACORRIENTE h=0.40m | 70d | 2023-02-11 | 2023-05-04 | 620SS | 148d | 0d | 42,434 | 05.03.10 |
| 622 | 1.6.3.11 | SALIDA DE CENTRO DE TOMACORRIENTES AREA DE COMPUTADORA | 70d | 2023-02-11 | 2023-05-04 | 621SS | 148d | 0d | 5,017.6 | 05.03.11 |
| 623 | 1.6.4 | **ILUMUNACION PATIO Y EXTERIOR** | 60d | 2023-03-30 | 2023-06-08 |  | 148d |  | 61,749.61 | 05.04 |
| 624 | 1.6.4.1 | SUMINISTRO Y MONTAJE DE POZO A TIERRA, INC. EXCAVACION | 60d | 2023-03-30 | 2023-06-08 | 622FS-30d | 148d | 0d | 14,991.99 | 05.04.01 |
| 625 | 1.6.4.2 | SUMINISTRO Y MONTAJE DE ARTEFACTO BRAQUETE LED (PARTE INTERIOR) | 60d | 2023-03-30 | 2023-06-08 | 624SS | 148d | 0d | 2,910.56 | 05.04.02 |
| 626 | 1.6.4.3 | SUMINISTRO E INSTALACION DE EQUIPO TIPO FAROLA CONICA C/LUMINARIA LED 30W YCONEXIONADO | 60d | 2023-03-30 | 2023-06-08 | 625SS | 148d | 0d | 25,908.12 | 05.04.03 |
| 627 | 1.6.4.4 | POSTE DE CONCRETO ARMADO DE 6m | 60d | 2023-03-30 | 2023-06-08 | 626SS | 148d | 0d | 16,687.8 | 05.04.04 |
| 628 | 1.6.4.5 | SUMINISTRO E INSTALACION DE REFLECTORES LED DE 100 WATTS | 60d | 2023-03-30 | 2023-06-08 | 627SS | 148d | 0d | 1,251.14 | 05.04.05 |

| ID | WBS | Task | Duration | Start | Finish | Predecessors | Total slack | Free slack | Cost | Text1 |
| --- | --- | --- | --- | --- | --- | --- | --- | --- | --- | --- |
| 629 | 1.6.5 | **OTROS** | 20d | 2023-05-22 | 2023-06-14 |  | 148d |  | 20,254.79 | 05.05 |
| 630 | 1.6.5.1 | SUMINISTRO Y MONTAJE DE ELECTROBOMBA Y ACCESORIOS | 20d | 2023-05-22 | 2023-06-14 | 628FS-15d | 148d | 0d | 4,677.55 | 05.05.01 |
| 631 | 1.6.5.2 | SUMINISTRO Y MONTAJE DE ALTAVOZ EXTERIOR PATIO | 20d | 2023-05-22 | 2023-06-14 | 630SS | 148d | 0d | 3,819.94 | 05.05.02 |
| 632 | 1.6.5.3 | SUMINISTRO Y MONTAJE DE TIMBRE | 20d | 2023-05-22 | 2023-06-14 | 631SS | 148d | 0d | 749.84 | 05.05.03 |
| 633 | 1.6.5.4 | SUMINISTRO Y MONTAJE DE EQUIPO DE LUZ DE EMERGENCIA | 20d | 2023-05-22 | 2023-06-14 | 632SS | 148d | 0d | 10,150.92 | 05.05.04 |
| 634 | 1.6.5.5 | DESMONTAJE DE POSTES | 20d | 2023-05-22 | 2023-06-14 | 633SS | 148d | 0d | 856.54 | 05.05.05 |
| 635 | 1.6.6 | **SISTEMA DE ILUMINACION FOTOVOLTAICO PARA CAMPO DE FULBITO** | 30d | 2023-06-02 | 2023-07-07 |  | 148d |  | 36,272.34 | 05.06 |
| 636 | 1.6.6.1 | SISTEMA DE EQUIPO SOLAR, INCL. PANEL BATERIA, CONTROLADOR, CABLEADO, ACC. | 30d | 2023-06-02 | 2023-07-07 | 634FS-10d | 148d | 0d | 27,641.78 | 05.06.01 |
| 637 | 1.6.6.2 | SUMINISTRO E INSTALACION DE REFLECTOR TIPO LED DE 200W C/EQUIPO INCORPORADO | 30d | 2023-06-02 | 2023-07-07 | 636SS | 148d | 0d | 8,430.56 | 05.06.02 |
| 638 | 1.6.6.3 | SUMINISTRO E NSTALACION DE ACCESRIOS | 30d | 2023-06-02 | 2023-07-07 | 637SS | 148d | 0d | 200 | 05.06.03 |
| 639 | 1.6.7 | **SUMINISTRO DE ILUMINACION PARA CAMPO DE FUTBOL** | 15d | 2023-07-07 | 2023-07-25 |  | 148d |  | 50,050.5 | 05.07 |
| 640 | 1.6.7.1 | SUMINISTRO E INSTALACION DE REFLECTORES LED DE 200 WATTS INCORPORADO | 15d | 2023-07-07 | 2023-07-25 | 638 | 148d | 0d | 37,534.2 | 05.07.01 |
| 641 | 1.6.7.2 | IZAJE Y CIMENTACION DE POSTE DE CONCRETO DE 11m CON PROTECCION CONOCA EN LA BASE | 15d | 2023-07-07 | 2023-07-25 | 640SS | 173d | 0d | 11,178.8 | 05.07.02 |
| 642 | 1.6.7.3 | EXCAVACION DE HOYO PARA POSTES DE CONCRETO DE 11m EN TERRENO NORMAL HOYOS DE 0.6m DE Ø, Y 1.50m DE PROFUNDIDAD | 15d | 2023-07-07 | 2023-07-25 | 641SS | 173d | 0d | 977.5 | 05.07.03 |
| 643 | 1.6.7.4 | EMPALME CONEXIONES ELECTRICAS | 15d | 2023-07-07 | 2023-07-25 | 642SS | 173d | 0d | 360 | 05.07.04 |
| 644 | 1.6.8 | **AIRE ACONDICIONADO** | 15d | 2023-07-25 | 2023-08-11 |  | 173d |  | 36,489.12 | 05.08 |
| 645 | 1.6.8.1 | SUMINISTRO E INSTALACION DE EQUIPO DE AIRE ACONDICIONADO DE 24000 BTU, INC. CONDENSADOR Y ACCESORIOS | 15d | 2023-07-25 | 2023-08-11 | 643 | 173d | 0d | 29,388.58 | 05.08.01 |
| 646 | 1.6.8.2 | SUMINISTRO E INSTALACION DE EQUIPO DE AIRE ACONDICIONADO DE 18000 BTU, INC. CONDENSADOR Y ACCESORIOS | 15d | 2023-07-25 | 2023-08-11 | 645SS | 173d |  | 7,100.54 | 05.08.02 |
| 647 | 1.6.9 | **SUMINISTRO E INSTALACION DE GRUPO GENERADOR** | 65d | 2023-05-22 | 2023-08-05 |  | 175d |  | 38,020.73 | 05.09 |
| 648 | 1.6.9.1 | SUMINISTRO Y MONTAJE DE GRUPO GENERADOR DE 50HP, ENCAPSULADO | 60d | 2023-05-22 | 2023-07-31 | 634SS | 175d | 0d | 27,842.14 | 05.09.01 |
| 649 | 1.6.9.2 | SUMINISTRO E INSTALACION DE TABLERO DE TRANSFERENCIA | 15d | 2023-07-19 | 2023-08-05 | 648FS-10d | 175d | 0d | 10,178.59 | 05.09.02 |
| 650 | 1.6.10 | **SUMINISTRO Y PRUEBAS DE RED ELECTRICA** | 6d | 2023-08-02 | 2023-08-09 |  | 175d |  | 649.57 | 05.10 |
| 651 | 1.6.10.1 | PRUEBAS DE RED ELECTRICAS EN BAJA TENSION | 6d | 2023-08-02 | 2023-08-09 | 649FS-3d | 175d |  | 649.57 | 05.10.01 |
| 652 | 1.6.11 | **SUMINISTRO E INSTALACION DE REDES DATA** | 30d | 2023-07-07 | 2023-08-11 |  | 148d |  | 10,848.58 | 05.11 |
| 653 | 1.6.11.1 | SUMINISTRO Y MONTAJE DE ACCESORIOS PARA SISTEMA DE DATA INTERNET (INCLUYE CONTRATO) | 30d | 2023-07-07 | 2023-08-11 | 640SS | 148d | 0d | 10,494.58 | 05.11.01 |
| 654 | 1.6.11.2 | ESTRUCTURA DE PROYECCION | 30d | 2023-07-07 | 2023-08-11 | 653SS | 158d | 0d | 354 | 05.11.02 |

| ID | WBS | Task | Duration | Start | Finish | Predecessors | Total slack | Free slack | Cost | Text1 |
| --- | --- | --- | --- | --- | --- | --- | --- | --- | --- | --- |
| 655 | 1.6.12 | **TRANSPORTE DE MATERIALES** | 10d | 2022-12-21 | 2023-01-02 |  | 363d |  | 3,500 | 05.12 |
| 656 | 1.6.12.1 | TRANSPORTE DE MATERIALES, EXPED. REPLANTEO | 10d | 2022-12-21 | 2023-01-02 | 601SS | 363d |  | 3,500 | 05.12.01 |
| 657 | 1.6.13 | **SEGURIDAD DE OBRA** | 200d | 2022-12-21 | 2023-08-11 |  | 173d |  | 800 | 05.13 |
| 658 | 1.6.13.1 | SEÑALIZACION DE RIESGO ELECTRICO | 200d | 2022-12-21 | 2023-08-11 | 601SS | 173d |  | 800 | 05.13.01 |
| 659 | 1.6.14 | **DERECHO DE CONEXION - ENOSA** | 45d | 2023-07-07 | 2023-08-29 |  | 158d |  | 2,745.15 | 05.14 |
| 660 | 1.6.14.1 | DERECHO DE RECONEXION - ENOSA | 45d | 2023-07-07 | 2023-08-29 | 654SS | 158d | 0d | 660 | 05.14.01 |
| 661 | 1.6.14.2 | REUBICACION DE ACOMETIDA TRIFASICA (ESP. TECNICAS) | 45d | 2023-07-07 | 2023-08-29 | 660SS | 158d | 0d | 2,085.15 | 05.14.02 |
| 662 | 1.6.15 | **PARARRAYOS** | 45d | 2023-07-07 | 2023-08-29 |  | 158d |  | 5,324.16 | 05.15 |
| 663 | 1.6.15.1 | SUMINISTRO Y MONTAJE DE PARARRAYOS | 45d | 2023-07-07 | 2023-08-29 | 661SS | 158d |  | 5,324.16 | 05.15.01 |
| 664 | 1.7 | **MOBILIARIO Y EQUIPAMIENTO** | 90d | 2023-11-16 | 2024-02-29 |  | 0d |  | 2,023,195 | 06 |
| 665 | 1.7.1 | **MOBILIARIO** | 90d | 2023-11-16 | 2024-02-29 |  | 0d |  | 1,018,735 | 06.01 |
| 666 | 1.7.1.1 | **MESAS** | 90d | 2023-11-16 | 2024-02-29 |  | 0d |  | 266,518 | 06.01.01 |
| 667 | 1.7.1.1.1 | MESA RECTANGULAR PARA ESTUDIANTE (0.60 M X 0.50 M X 0.56 M) | 90d | 2023-11-16 | 2024-02-29 | 305SS-12d | 0d |  | 31,500 | 06.01.01.01 |
| 668 | 1.7.1.1.2 | MESA RECTANGULAR PARA ESTUDIANTE (0.60 M X 0.50 M X 0.61 M) | 90d | 2023-11-16 | 2024-02-29 | 667SS | 0d |  | 36,000 | 06.01.01.02 |
| 669 | 1.7.1.1.3 | MESA RECTANGULAR PARA ESTUDIANTE (0.60 M X 0.50 M X 0.66 M) | 90d | 2023-11-16 | 2024-02-29 | 668SS | 0d |  | 37,200 | 06.01.01.03 |
| 670 | 1.7.1.1.4 | MESA RECTANGULAR PARA ESTUDIANTE (0.60 M X 0.50 M X 0.69 M) | 90d | 2023-11-16 | 2024-02-29 | 669SS | 0d |  | 41,850 | 06.01.01.04 |
| 671 | 1.7.1.1.5 | MESA RECTANGULAR PARA ESTUDIANTE (0.60 M X 0.50 M X 0.72 M) | 90d | 2023-11-16 | 2024-02-29 | 670SS | 0d |  | 38,400 | 06.01.01.05 |
| 672 | 1.7.1.1.6 | MESA RECTANGULAR PARA ESTUDIANTE (0.60 M X 0.50 M X 0.75 M) | 90d | 2023-11-16 | 2024-02-29 | 671SS | 0d |  | 19,200 | 06.01.01.06 |
| 673 | 1.7.1.1.7 | MESA RECTANGULAR PARA DOCENTE (1.00 M X 0.50 M X 0.75 M) | 90d | 2023-11-16 | 2024-02-29 | 672SS | 0d |  | 16,588 | 06.01.01.07 |
| 674 | 1.7.1.1.8 | MESA RECTANGULAR PARA ESTUDIANTE (0.90 M X 0.45 M X 0.75 M) | 90d | 2023-11-16 | 2024-02-29 | 673SS | 0d |  | 1,500 | 06.01.01.08 |
| 675 | 1.7.1.1.9 | MESA RECTANGULAR DE (1.20 M X 0.80 M X 0.75 M) | 90d | 2023-11-16 | 2024-02-29 | 674SS | 0d |  | 3,850 | 06.01.01.09 |
| 676 | 1.7.1.1.10 | MESA RECTANGULAR REGULABLE PARA ESTUDIANTE (1.50 M X 0.90 M X 0.69 M A 0.75 M) | 90d | 2023-11-16 | 2024-02-29 | 675SS | 0d |  | 2,250 | 06.01.01.10 |
| 677 | 1.7.1.1.11 | MESA RECTANGULAR REGULABLE PARA 6 ESTUDIANTES (2.00 M X 1.00 M X 0.56 M A 0.66 M) | 90d | 2023-11-16 | 2024-02-29 | 676SS | 0d |  | 10,000 | 06.01.01.11 |
| 678 | 1.7.1.1.12 | MESA RECTANGULAR REGULABLE PARA 6 ESTUDIANTES (2.00 M X 1.00 M X 0.69 M A 0.75 M) | 90d | 2023-11-16 | 2024-02-29 | 677SS | 0d |  | 25,000 | 06.01.01.12 |
| 679 | 1.7.1.1.13 | MESA DE CENTRO O DE REVISTAS | 90d | 2023-11-16 | 2024-02-29 | 678SS | 0d |  | 1,000 | 06.01.01.13 |
| 680 | 1.7.1.1.14 | MESA DE TRABAJO (2.40 M X 0.60 M) | 90d | 2023-11-16 | 2024-02-29 | 679SS | 0d |  | 420 | 06.01.01.14 |
| 681 | 1.7.1.1.15 | MESAS MODULARES (1.00 M X 1.00 M) | 90d | 2023-11-16 | 2024-02-29 | 680SS | 0d |  | 1,760 | 06.01.01.15 |

| ID | WBS | Task | Duration | Start | Finish | Predecessors | Total slack | Cost | Text1 |
| --- | --- | --- | --- | --- | --- | --- | --- | --- | --- |
| 682 | 1.7.1.2 | **ESCRITORIOS** | 90d | 2023-11-16 | 2024-02-29 |  | 0d | 11,520 | 06.01.02 |
| 683 | 1.7.1.2.1 | ESCRITORIO CON CAJONERA PARA DOCENTE (1.00 M X 0.50 M X 0.75 M) | 90d | 2023-11-16 | 2024-02-29 | 681SS | 0d | 5,850 | 06.01.02.01 |
| 684 | 1.7.1.2.2 | ESCRITORIO PARA COMPUTADORA (1.00 M X 0.60 M X 0.75 M) | 90d | 2023-11-16 | 2024-02-29 | 683SS | 0d | 5,320 | 06.01.02.02 |
| 685 | 1.7.1.2.3 | ESCRITORIO PARA COMPUTADORA (0.80 M X 0.60 M X 0.75 M) | 90d | 2023-11-16 | 2024-02-29 | 684SS | 0d | 350 | 06.01.02.03 |
| 686 | 1.7.1.3 | **SILLAS** | 90d | 2023-11-16 | 2024-02-29 |  | 0d | 267,400 | 06.01.03 |
| 687 | 1.7.1.3.1 | SILLA PARA ESTUDIANTE (0.27 M X 0.32 M X 0.30 M) | 90d | 2023-11-16 | 2024-02-29 | 685SS | 0d | 22,050 | 06.01.03.01 |
| 688 | 1.7.1.3.2 | SILLA PARA ESTUDIANTE (0.30 M X 0.34 M X 0.34 M) | 90d | 2023-11-16 | 2024-02-29 | 687SS | 0d | 25,200 | 06.01.03.02 |
| 689 | 1.7.1.3.3 | SILLA PARA ESTUDIANTE (0.33 M X 0.36 M X 0.36 M) | 90d | 2023-11-16 | 2024-02-29 | 688SS | 0d | 26,400 | 06.01.03.03 |
| 690 | 1.7.1.3.4 | SILLA PARA ESTUDIANTE (0.36 M X 0.38 M X 0.39 M) | 90d | 2023-11-16 | 2024-02-29 | 689SS | 0d | 33,750 | 06.01.03.04 |
| 691 | 1.7.1.3.5 | SILLA PARA ESTUDIANTE (0.38 M X 0.40 M X 0.42 M) | 90d | 2023-11-16 | 2024-02-29 | 690SS | 0d | 30,000 | 06.01.03.05 |
| 692 | 1.7.1.3.6 | SILLA PARA ESTUDIANTE (0.38 M X 0.41 M X 0.45 M) | 90d | 2023-11-16 | 2024-02-29 | 691SS | 0d | 15,600 | 06.01.03.06 |
| 693 | 1.7.1.3.7 | SILLA REGULABLE 3 NIVELES PARA ESTUDIANTE (0.33 M X 0.36 M X 0.30 M A 0.36 M) | 90d | 2023-11-16 | 2024-02-29 | 692SS | 0d | 18,000 | 06.01.03.07 |
| 694 | 1.7.1.3.8 | SILLA REGULABLE 3 NIVELES PARA ESTUDIANTE (0.38 M X 0.41 M X 0.39M A 0.45 M) | 90d | 2023-11-16 | 2024-02-29 | 693SS | 0d | 43,200 | 06.01.03.08 |
| 695 | 1.7.1.3.9 | SILLA PARA DOCENTE (0.40 M X 0.36 M X 0.45 M) | 90d | 2023-11-16 | 2024-02-29 | 694SS | 0d | 13,130 | 06.01.03.09 |
| 696 | 1.7.1.3.10 | BANCOS DE MADERA | 90d | 2023-11-16 | 2024-02-29 | 695SS | 0d | 6,600 | 06.01.03.10 |
| 697 | 1.7.1.3.11 | SILLAS APILABLES | 90d | 2023-11-16 | 2024-02-29 | 696SS | 0d | 25,740 | 06.01.03.11 |
| 698 | 1.7.1.3.12 | SILLÓN (0.60 M X 0.55 M X 0.44 M) | 90d | 2023-11-16 | 2024-02-29 | 697SS | 0d | 2,160 | 06.01.03.12 |
| 699 | 1.7.1.3.13 | SILLA GIRATORIA | 90d | 2023-11-16 | 2024-02-29 | 698SS | 0d | 2,700 | 06.01.03.13 |
| 700 | 1.7.1.3.14 | SILLA GERENCIAL GIRATORIA | 90d | 2023-11-16 | 2024-02-29 | 699SS | 0d | 410 | 06.01.03.14 |
| 701 | 1.7.1.3.15 | SOFA DOBLE | 90d | 2023-11-16 | 2024-02-29 | 700SS | 0d | 2,460 | 06.01.03.15 |
| 702 | 1.7.1.4 | **MUEBLES PARA GUARDADO** | 90d | 2023-11-16 | 2024-02-29 |  | 0d | 312,117 | 06.01.04 |
| 703 | 1.7.1.4.1 | ARMARIO 4 DIVISIONES PARA DOCENTE (0.90 M X 0.45 M X 1.80 M) | 90d | 2023-11-16 | 2024-02-29 | 701SS | 0d | 101,250 | 06.01.04.01 |
| 704 | 1.7.1.4.2 | ARMARIO 5 DIVISIONES PARA DOCENTE (0.90 M X 0.45 M X 1.80 M) | 90d | 2023-11-16 | 2024-02-29 | 703SS | 0d | 1,250 | 06.01.04.02 |
| 705 | 1.7.1.4.3 | ESTANTE 4 DIVISIONES PARA ESTUDIANTE (0.80 M X 0.30 M X 1.50 M) | 90d | 2023-11-16 | 2024-02-29 | 704SS | 0d | 41,895 | 06.01.04.03 |
| 706 | 1.7.1.4.4 | ESTANTE 5 DIVISIONES (0.80 M X 0.30 M X 1.50 M) | 90d | 2023-11-16 | 2024-02-29 | 705SS | 0d | 887 | 06.01.04.04 |
| 707 | 1.7.1.4.5 | CASILLEROS PARA ESTUDIANTE (1.20 M X 0.40 M X 1.20 M) | 90d | 2023-11-16 | 2024-02-29 | 706SS | 0d | 20,815 | 06.01.04.05 |
| 708 | 1.7.1.4.6 | CASILLEROS PARA ESTUDIANTE (1.20 M X 0.40 M X 1.80 M) | 90d | 2023-11-16 | 2024-02-29 | 707SS | 0d | 26,250 | 06.01.04.06 |
| 709 | 1.7.1.4.7 | EXHIBIDOR DE LIBROS 2 DIVISIONES (0.90 M X 0.40 M X 0.90 M) | 90d | 2023-11-16 | 2024-02-29 | 708SS | 0d | 41,800 | 06.01.04.07 |
| 710 | 1.7.1.4.8 | EXHIBIDOR DE LIBROS (1.20 M X 0.40 M X 0.85 M) | 90d | 2023-11-16 | 2024-02-29 | 709SS | 0d | 10,200 | 06.01.04.08 |
| 711 | 1.7.1.4.9 | MUEBLE ALTO 2 DIVISIONES (0.90 M X 0.40 M X 0.50 M) | 90d | 2023-11-16 | 2024-02-29 | 710SS | 0d | 37,400 | 06.01.04.09 |
| 712 | 1.7.1.4.10 | MUEBLE BAJO 2 DIVISIONES (0.80 M X 0.40 M X 1.00 M) | 90d | 2023-11-16 | 2024-02-29 | 711SS | 0d | 1,740 | 06.01.04.10 |
| 713 | 1.7.1.4.11 | MUEBLE BAJO 2 DIVISIONES (0.90 M X 0.40 M X 1.00 M) | 90d | 2023-11-16 | 2024-02-29 | 712SS | 0d | 26,680 | 06.01.04.11 |
| 714 | 1.7.1.4.12 | ESTANTES MOBILES (0.80x3.00 m) | 90d | 2023-11-16 | 2024-02-29 | 713SS | 0d | 1,950 | 06.01.04.12 |

| ID | WBS | Task | Duration | Start | Finish | Predecessors | Total slack | Cost | Text1 |
| --- | --- | --- | --- | --- | --- | --- | --- | --- | --- |
| 715 | 1.7.1.5 | **PIZARRA ACRILICA** | 90d | 2023-11-16 | 2024-02-29 |  | 0d | 42,700 | 06.01.05 |
| 716 | 1.7.1.5.1 | PIZARRA ACRÍLICA DE (3.20 M X 1.20 M) | 90d | 2023-11-16 | 2024-02-29 | 714SS | 0d | 42,000 | 06.01.05.01 |
| 717 | 1.7.1.5.2 | PIZARRA ACRÍLICA DE (1.80 M X 1.20 M) | 90d | 2023-11-16 | 2024-02-29 | 716SS | 0d | 700 | 06.01.05.02 |
| 718 | 1.7.1.6 | **PANTALLA ECRAN** | 90d | 2023-11-16 | 2024-02-29 |  | 0d | 77,000 | 06.01.06 |
| 719 | 1.7.1.6.1 | PANTALLA ECRAN RETRACTIL DE 72" | 90d | 2023-11-16 | 2024-02-29 | 717SS | 0d | 77,000 | 06.01.06.01 |
| 720 | 1.7.1.7 | **RACK** | 90d | 2023-11-16 | 2024-02-29 |  | 0d | 7,250 | 06.01.07 |
| 721 | 1.7.1.7.1 | RACK PARA PROYECTOR MULTIMEDIA | 90d | 2023-11-16 | 2024-02-29 | 719SS | 0d | 5,500 | 06.01.07.01 |
| 722 | 1.7.1.7.2 | RACK PARA TV Y REPRODUCTOR BLU - RAY | 90d | 2023-11-16 | 2024-02-29 | 721SS | 0d | 900 | 06.01.07.02 |
| 723 | 1.7.1.7.3 | RACK PARA LAPTOPS (0.60 M X 0.45 M) DE CAPACIDAD 16 LAPTOPS | 90d | 2023-11-16 | 2024-02-29 | 722SS | 0d | 850 | 06.01.07.03 |
| 724 | 1.7.1.8 | **GABINETE** | 90d | 2023-11-16 | 2024-02-29 |  | 0d | 2,900 | 06.01.08 |
| 725 | 1.7.1.8.1 | GABINETE 9RU PARA EMPOTRAR INC. RACK | 90d | 2023-11-16 | 2024-02-29 | 723SS | 0d | 2,900 | 06.01.08.01 |
| 726 | 1.7.1.9 | **MOBILIARIO COMPLEMENTARIO** | 90d | 2023-11-16 | 2024-02-29 |  | 0d | 31,330 | 06.01.09 |
| 727 | 1.7.1.9.1 | BOTIQUIN | 90d | 2023-11-16 | 2024-02-29 | 725SS | 0d | 200 | 06.01.09.01 |
| 728 | 1.7.1.9.2 | COCHE DE MÚLTIPLES USOS | 90d | 2023-11-16 | 2024-02-29 | 727SS | 0d | 420 | 06.01.09.02 |
| 729 | 1.7.1.9.3 | CAMILLA RODANTE (0.70 M X 1.80 M) | 90d | 2023-11-16 | 2024-02-29 | 728SS | 0d | 600 | 06.01.09.03 |
| 730 | 1.7.1.9.4 | ANAQUELES METÁLICOS (0.95 M X 0.45 M) | 90d | 2023-11-16 | 2024-02-29 | 729SS | 0d | 8,360 | 06.01.09.04 |
| 731 | 1.7.1.9.5 | UTENSILIOS DE COCINA | 90d | 2023-11-16 | 2024-02-29 | 730SS | 0d | 1,000 | 06.01.09.05 |
| 732 | 1.7.1.9.6 | JUEGO DE OLLAS INDUSTRIALES | 90d | 2023-11-16 | 2024-02-29 | 731SS | 0d | 4,800 | 06.01.09.06 |
| 733 | 1.7.1.9.7 | JUEGO DE CUBIERTOS (CUCHARA, CUCHARITA, TENEDOR Y CUCHILLO) | 90d | 2023-11-16 | 2024-02-29 | 732SS | 0d | 3,920 | 06.01.09.07 |
| 734 | 1.7.1.9.8 | VAJILLA ( PLATO TENDIDO, PLATO HONDO, VASO Y TASA) | 90d | 2023-11-16 | 2024-02-29 | 733SS | 0d | 5,880 | 06.01.09.08 |
| 735 | 1.7.1.9.9 | LOCKERS (0.40 M X 0.45 M) | 90d | 2023-11-16 | 2024-02-29 | 734SS | 0d | 4,800 | 06.01.09.09 |
| 736 | 1.7.1.9.10 | ARCHIVADORES 0.45 M X 0.70 M | 90d | 2023-11-16 | 2024-02-29 | 735SS | 0d | 1,350 | 06.01.09.10 |
| 737 | 1.7.2 | **EQUIPAMIENTO** | 90d | 2023-11-16 | 2024-02-29 |  | 0d | 964,460 | 06.02 |
| 738 | 1.7.2.1 | **EQUIPOS MULTIMEDIA** | 90d | 2023-11-16 | 2024-02-29 |  | 0d | 95,415 | 06.02.01 |
| 739 | 1.7.2.1.1 | PROYECTOR MULTIMEDIA | 90d | 2023-11-16 | 2024-02-29 | 736SS | 0d | 84,425 | 06.02.01.01 |
| 740 | 1.7.2.1.2 | IMPRESORA MULTIFUNCIONAL | 90d | 2023-11-16 | 2024-02-29 | 739SS | 0d | 10,990 | 06.02.01.02 |

| ID | WBS | Task | Duration | Start | Finish | Predecessors | Total slack | Cost | Text1 |
| --- | --- | --- | --- | --- | --- | --- | --- | --- | --- |
| 741 | 1.7.2.2 | **PC Y/O LAPTOP** | 90d | 2023-11-16 | 2024-02-29 |  | 0d | 575,925 | 06.02.02 |
| 742 | 1.7.2.2.1 | SWITCH 48 PUERTOS 10/100/1000 Mbps | 90d | 2023-11-16 | 2024-02-29 | 740SS | 0d | 3,400 | 06.02.02.01 |
| 743 | 1.7.2.2.2 | PC- CORE I7 3.4 GHZ, MONITOR 24" FHD, RAM 16GB, DISCO ITB + TECLADO Y MOUSE | 90d | 2023-11-16 | 2024-02-29 | 742SS | 0d | 44,685 | 06.02.02.02 |
| 744 | 1.7.2.2.3 | LAPTOP CORE I5 -10 GENERACION, RAM 8GB, 512 GB, PANTALLA 15.6" + MOUSE | 90d | 2023-11-16 | 2024-02-29 | 743SS | 0d | 527,840 | 06.02.02.03 |
| 745 | 1.7.2.3 | **TV Y EQUIPOS ELECTRICOS** | 90d | 2023-11-16 | 2024-02-29 |  | 0d | 64,775 | 06.02.03 |
| 746 | 1.7.2.3.1 | TELEVISOR DE 55" HD SMART TV | 90d | 2023-11-16 | 2024-02-29 | 744SS | 0d | 13,495 | 06.02.03.01 |
| 747 | 1.7.2.3.2 | REPRODUCTOR BLU - RAY | 90d | 2023-11-16 | 2024-02-29 | 746SS | 0d | 1,900 | 06.02.03.02 |
| 748 | 1.7.2.3.3 | CÁMARA FOTOGRÁFICA | 90d | 2023-11-16 | 2024-02-29 | 747SS | 0d | 9,500 | 06.02.03.03 |
| 749 | 1.7.2.3.4 | PIZARRA INTERACTIVA | 90d | 2023-11-16 | 2024-02-29 | 748SS | 0d | 27,000 | 06.02.03.04 |
| 750 | 1.7.2.3.5 | ESTABILIZADOR | 90d | 2023-11-16 | 2024-02-29 | 749SS | 0d | 1,530 | 06.02.03.05 |
| 751 | 1.7.2.3.6 | POWER RACK | 90d | 2023-11-16 | 2024-02-29 | 750SS | 0d | 600 | 06.02.03.06 |
| 752 | 1.7.2.3.7 | UPS 1000VA, 600W | 90d | 2023-11-16 | 2024-02-29 | 751SS | 0d | 2,500 | 06.02.03.07 |
| 753 | 1.7.2.3.8 | UNIDAD DE DISTRIBUCIÓN ENERGÉTICA PDU ACCESS POINT DE ROUTER AC1200/2.4 Y 5GHZ | 90d | 2023-11-16 | 2024-02-29 | 752SS | 0d | 8,250 | 06.02.03.08 |
| 754 | 1.7.2.4 | **EQUIPO LABORATORIO** | 90d | 2023-11-16 | 2024-02-29 |  | 0d | 52,451 | 06.02.04 |
| 755 | 1.7.2.4.1 | BALANZA DE PRECISIÓN | 90d | 2023-11-16 | 2024-02-29 | 753SS | 0d | 1,110 | 06.02.04.01 |
| 756 | 1.7.2.4.2 | ESTERILIZADOR | 90d | 2023-11-16 | 2024-02-29 | 755SS | 0d | 3,600 | 06.02.04.02 |
| 757 | 1.7.2.4.3 | CENTRIFUGA | 90d | 2023-11-16 | 2024-02-29 | 756SS | 0d | 4,700 | 06.02.04.03 |
| 758 | 1.7.2.4.4 | DESTILADORA DE AGUA | 90d | 2023-11-16 | 2024-02-29 | 757SS | 0d | 3,900 | 06.02.04.04 |
| 759 | 1.7.2.4.5 | MEDIDOR PORTÁTIL DE PH | 90d | 2023-11-16 | 2024-02-29 | 758SS | 0d | 2,970 | 06.02.04.05 |
| 760 | 1.7.2.4.6 | EQUIPO BAÑO MARÍA | 90d | 2023-11-16 | 2024-02-29 | 759SS | 0d | 3,500 | 06.02.04.06 |
| 761 | 1.7.2.4.7 | MICROSCOPIO DIGITAL | 90d | 2023-11-16 | 2024-02-29 | 760SS | 0d | 5,830 | 06.02.04.07 |
| 762 | 1.7.2.4.8 | MICROSCOPIO BINOCULARES | 90d | 2023-11-16 | 2024-02-29 | 761SS | 0d | 3,380 | 06.02.04.08 |
| 763 | 1.7.2.4.9 | TERMÓMETRO TIPO LAPICERO | 90d | 2023-11-16 | 2024-02-29 | 762SS | 0d | 281 | 06.02.04.09 |
| 764 | 1.7.2.4.10 | ESQUELETO HUMANO INTERACTIVO | 90d | 2023-11-16 | 2024-02-29 | 763SS | 0d | 4,900 | 06.02.04.10 |
| 765 | 1.7.2.4.11 | MAQUETAS CIRCUITOS ELÉCTRICOS Y ELECTRÓNICOS | 90d | 2023-11-16 | 2024-02-29 | 764SS | 0d | 12,220 | 06.02.04.11 |
| 766 | 1.7.2.4.12 | KIT PARA ESTUDIO DE CÓDIGO GENÉTICO | 90d | 2023-11-16 | 2024-02-29 | 765SS | 0d | 6,060 | 06.02.04.12 |

| ID | WBS | Task | Duration | Start | Finish | Predecessors | Total slack | Cost | Text1 |
| --- | --- | --- | --- | --- | --- | --- | --- | --- | --- |
| 767 | 1.7.2.5 | **EQUIPO TALLERES/CRT** | 90d | 2023-11-16 | 2024-02-29 |  | 0d | 6,868 | 06.02.05 |
| 768 | 1.7.2.5.1 | KIT DE DISEÑO O TRABAJO | 90d | 2023-11-16 | 2024-02-29 | 766SS | 0d | 318 | 06.02.05.01 |
| 769 | 1.7.2.5.2 | KIT DE MAPAS DE PERÚ | 90d | 2023-11-16 | 2024-02-29 | 768SS | 0d | 1,250 | 06.02.05.02 |
| 770 | 1.7.2.5.3 | KIT DE MAPAS DE CONTINENTES | 90d | 2023-11-16 | 2024-02-29 | 769SS | 0d | 1,400 | 06.02.05.03 |
| 771 | 1.7.2.5.4 | KIT SISTEMA SOLAR | 90d | 2023-11-16 | 2024-02-29 | 770SS | 0d | 1,250 | 06.02.05.04 |
| 772 | 1.7.2.5.5 | GLOBO TERRÁQUEO FÍSICO POLÍTICO CON PLANISFERIO | 90d | 2023-11-16 | 2024-02-29 | 771SS | 0d | 1,400 | 06.02.05.05 |
| 773 | 1.7.2.5.6 | EQUIPO DE CONSTRUCCIÓN GEOMÉTRICA | 90d | 2023-11-16 | 2024-02-29 | 772SS | 0d | 1,250 | 06.02.05.06 |
| 774 | 1.7.2.6 | **EQUIPO EDUCACION FISICA** | 90d | 2023-11-16 | 2024-02-29 |  | 0d | 95,556 | 06.02.06 |
| 775 | 1.7.2.6.1 | PARANTES CON SISTEMA TELESCOPICO | 90d | 2023-11-16 | 2024-02-29 | 773SS | 0d | 11,600 | 06.02.06.01 |
| 776 | 1.7.2.6.2 | NET DE VOLEY | 90d | 2023-11-16 | 2024-02-29 | 775SS | 0d | 556 | 06.02.06.02 |
| 777 | 1.7.2.6.3 | SILBATOS | 90d | 2023-11-16 | 2024-02-29 | 776SS | 0d | 2,100 | 06.02.06.03 |
| 778 | 1.7.2.6.4 | PELOTAS DE BÁSQUET N°7 | 90d | 2023-11-16 | 2024-02-29 | 777SS | 0d | 19,200 | 06.02.06.04 |
| 779 | 1.7.2.6.5 | TABURETES DE MADERA | 90d | 2023-11-16 | 2024-02-29 | 778SS | 0d | 13,440 | 06.02.06.05 |
| 780 | 1.7.2.6.6 | CRONÓMETRO DIGITAL A PILAS | 90d | 2023-11-16 | 2024-02-29 | 779SS | 0d | 5,100 | 06.02.06.06 |
| 781 | 1.7.2.6.7 | PELOTAS DE VOLEY | 90d | 2023-11-16 | 2024-02-29 | 780SS | 0d | 13,200 | 06.02.06.07 |
| 782 | 1.7.2.6.8 | PELOTAS DE FÚTBOL N°5 | 90d | 2023-11-16 | 2024-02-29 | 781SS | 0d | 12,000 | 06.02.06.08 |
| 783 | 1.7.2.6.9 | BALANZA ELECTRÓNICA | 90d | 2023-11-16 | 2024-02-29 | 782SS | 0d | 1,360 | 06.02.06.09 |
| 784 | 1.7.2.6.10 | COLCHONETAS | 90d | 2023-11-16 | 2024-02-29 | 783SS | 0d | 17,000 | 06.02.06.10 |
| 785 | 1.7.2.7 | **EQUIPAMIENTO DE BANDA** | 90d | 2023-11-16 | 2024-02-29 |  | 0d | 61,300 | 06.02.07 |
| 786 | 1.7.2.7.1 | TROMPETA | 90d | 2023-11-16 | 2024-02-29 | 784SS | 0d | 9,310 | 06.02.07.01 |
| 787 | 1.7.2.7.2 | BOMBO | 90d | 2023-11-16 | 2024-02-29 | 786SS | 0d | 1,590 | 06.02.07.02 |
| 788 | 1.7.2.7.3 | TAROLA | 90d | 2023-11-16 | 2024-02-29 | 787SS | 0d | 7,500 | 06.02.07.03 |
| 789 | 1.7.2.7.4 | PLATILLOS | 90d | 2023-11-16 | 2024-02-29 | 788SS | 0d | 5,600 | 06.02.07.04 |
| 790 | 1.7.2.7.5 | PANDERETA | 90d | 2023-11-16 | 2024-02-29 | 789SS | 0d | 1,200 | 06.02.07.05 |
| 791 | 1.7.2.7.6 | BAJO DE VIENTO | 90d | 2023-11-16 | 2024-02-29 | 790SS | 0d | 6,000 | 06.02.07.06 |
| 792 | 1.7.2.7.7 | LIRA ROMA | 90d | 2023-11-16 | 2024-02-29 | 791SS | 0d | 3,000 | 06.02.07.07 |
| 793 | 1.7.2.7.8 | TROMBON DE VARA | 90d | 2023-11-16 | 2024-02-29 | 792SS | 0d | 5,800 | 06.02.07.08 |
| 794 | 1.7.2.7.9 | CORNETA | 90d | 2023-11-16 | 2024-02-29 | 793SS | 0d | 2,500 | 06.02.07.09 |
| 795 | 1.7.2.7.10 | CLARINETE | 90d | 2023-11-16 | 2024-02-29 | 794SS | 0d | 7,500 | 06.02.07.10 |
| 796 | 1.7.2.7.11 | SAXO | 90d | 2023-11-16 | 2024-02-29 | 795SS | 0d | 10,500 | 06.02.07.11 |
| 797 | 1.7.2.7.12 | TAMBORES | 90d | 2023-11-16 | 2024-02-29 | 796SS | 0d | 800 | 06.02.07.12 |

| ID | WBS | Task | Type | Duration | Start | Finish | Predecessors | Total slack | Cost | Text1 |
| --- | --- | --- | --- | --- | --- | --- | --- | --- | --- | --- |
| 798 | 1.7.2.8 | **EQUIPO COMPLEMENTARIO** |  | 90d | 2023-11-16 | 2024-02-29 |  | 0d | 12,170 | 06.02.08 |
| 799 | 1.7.2.8.1 | EXTINTOR |  | 90d | 2023-11-16 | 2024-02-29 | 797SS | 0d | 320 | 06.02.08.01 |
| 800 | 1.7.2.8.2 | COCINA INDUSTRIAL 6 HORNILLAS |  | 90d | 2023-11-16 | 2024-02-29 | 799SS | 0d | 5,500 | 06.02.08.02 |
| 801 | 1.7.2.8.3 | CONGELADORA |  | 90d | 2023-11-16 | 2024-02-29 | 800SS | 0d | 1,450 | 06.02.08.03 |
| 802 | 1.7.2.8.4 | REFRIGERADORA |  | 90d | 2023-11-16 | 2024-02-29 | 801SS | 0d | 1,650 | 06.02.08.04 |
| 803 | 1.7.2.8.5 | FRIGO BAR |  | 90d | 2023-11-16 | 2024-02-29 | 802SS | 0d | 780 | 06.02.08.05 |
| 804 | 1.7.2.8.6 | LICUADORA |  | 90d | 2023-11-16 | 2024-02-29 | 803SS | 0d | 1,080 | 06.02.08.06 |
| 805 | 1.7.2.8.7 | BALÓN DE GAS Y ACCESORIOS |  | 90d | 2023-11-16 | 2024-02-29 | 804SS | 0d | 250 | 06.02.08.07 |
| 806 | 1.7.2.8.8 | MICROONDAS |  | 90d | 2023-11-16 | 2024-02-29 | 805SS | 0d | 1,140 | 06.02.08.08 |
| 807 | 1.7.3 | **TRANSPORTE DE MOBILIARIO Y EQUIPAMIENTO** |  | 90d | 2023-11-16 | 2024-02-29 |  | 0d | 40,000 | 06.03 |
| 808 | 1.7.3.1 | TRANSPORTE DE MOBILIARIO Y EQUIPAMIENTO A LA OBRA |  | 90d | 2023-11-16 | 2024-02-29 | 806SS | 0d | 40,000 | 06.03.01 |
| 809 | 1.8 | FIN DEL PROYECTO | milestone | 0d | 2024-02-29 | 2024-02-29 | 134, 808 | 0d |  |  |
